# Metering Competition external 2

Schedule from MS Project, 2015-03-26 to 2018-12-13.
AEMO

## Calendars

- Standard: Mon-Fri 08:00-12:00, 13:00-17:00; Sat-Sun off. Exceptions (off unless hours are given): 2015-06-08 (Queen's Birthday 2015), 2015-12-25 (Christmas Day 2015), 2015-12-28 (Boxing Day 2015), 2016-01-01 (New Year's Day 2016), 2016-01-26 (Australia Day 2016), 2016-03-25 (Easter Friday 2016), 2016-03-28 (Easter Monday 2016), 2016-04-25 (ANZAC Day 2016), 2016-06-13 (Queen's Birthday 2016), 2016-12-26 (Christmas Day 2016), 2016-12-27 (Boxing Day 2016), 2017-01-02 (New Year's Day 2017), 2017-01-26 (Australia Day 2017), 2017-04-14 (Easter Friday), 2017-04-17 (Easter Monday 2017), 2017-04-25 (ANZAC Day 2017), 2017-06-12 to 2017-06-16 (Queen's Birthday 2017), 2017-12-25 (Christmas Day 2017), 2017-12-26 (Boxing Day 2017).

## Schedule

| ID | WBS | Task | Type | Duration | Start | Finish | Predecessors | Total slack | Free slack | Constraint | Responsibility | Text Note |
| --- | --- | --- | --- | --- | --- | --- | --- | --- | --- | --- | --- | --- |
| 1 | 1 | **Metering Competition (MC)** |  | 681d | 2015-03-26 | 2017-12-01 |  | 0d |  |  |  |  |
| 2 | 1.1 | **Rule Change (MC)** |  | 175d | 2015-03-26 | 2015-11-26 |  | 0d |  |  |  |  |
| 3 | 1.1.1 | Draft Determination |  | 1d | 2015-03-26 | 2015-03-26 |  | 0d |  | must finish on 2015-03-26 |  |  |
| 4 | 1.1.2 | R - Draft Determination | milestone | 0d | 2015-03-26 | 2015-03-26 | 3 | 959d |  |  |  |  |
| 5 | 1.1.3 | Consultation Submissions |  | 40d | 2015-03-27 | 2015-05-21 | 3 | 0d |  | must start on 2015-03-27 | AEMC |  |
| 6 | 1.1.4 | Final Determination |  | 116d | 2015-06-18 | 2015-11-26 | 5 | 267d | 0d | finish no earlier than 2015-11-26 | AEMC |  |
| 7 | 1.1.5 | R - Final Determination | milestone | 0d | 2015-11-26 | 2015-11-26 | 6 | 785d |  |  |  |  |
| 8 | 1.2 | **Procedure Change (MC)** |  | 626d | 2015-06-11 | 2017-11-30 |  | 268d |  |  |  |  |
| 9 | 1.2.1 | Initial workshop (BMRG) |  | 1d | 2015-06-11 | 2015-06-11 | 5FS+13d | 905d |  |  | AEMO |  |
| 10 | 1.2.2 | Initial workshop (MSWG) |  | 1d | 2015-06-25 | 2015-06-25 | 5FS+23d | 895d |  |  | AEMO |  |
| 11 | 1.2.3 | Initial workshop (MRG) |  | 1d | 2015-06-22 | 2015-06-22 | 5FS+20d | 898d |  |  | AEMO |  |
| 12 | 1.2.4 | **Work Pkg 1a** |  | 64d | 2015-11-27 | 2016-03-01 |  | 276d |  |  |  |  |
| 13 | 1.2.4.1 | Produce workshop #1 material - Work Pkg 1a |  | 5d | 2015-11-27 | 2015-12-03 | 6 | 276d | 0d |  | AEMO |  |
| 14 | 1.2.4.2 | Send WG workshop #1 material - Work Pkg 1a |  | 1d | 2015-12-04 | 2015-12-04 | 13 | 276d | 0d | start no earlier than 2015-07-08 | AEMO |  |
| 15 | 1.2.4.3 | WG workshop #1 - Work Pkg 1a |  | 2d | 2015-12-17 | 2015-12-18 | 14FS+8d | 276d | 0d |  | Industry |  |
| 16 | 1.2.4.4 | Develop draft procedure #3 - Work Pkg 1a |  | 17d | 2015-12-21 | 2016-01-15 | 15 | 276d | 0d |  | AEMO | Allow extra time for holiday period |
| 17 | 1.2.4.5 | Send WG workshop #3 material - Work Pkg 1a |  | 1d | 2016-01-18 | 2016-01-18 | 16 | 276d | 0d |  | AEMO |  |
| 18 | 1.2.4.6 | WG workshop #3 - Work Pkg 1a |  | 2d | 2016-02-01 | 2016-02-02 | 17FS+8d | 276d | 0d |  | Industry |  |
| 19 | 1.2.4.7 | Update draft procedure #5 - Work Pkg 1a |  | 10d | 2016-02-03 | 2016-02-16 | 18 | 276d | 0d |  | AEMO |  |
| 20 | 1.2.4.8 | Send WG workshop #5 material - Work Pkg 1a |  | 1d | 2016-02-17 | 2016-02-17 | 19 | 718d |  |  |  |  |
| 21 | 1.2.4.9 | WG workshop #5 - Work Pkg 1a |  | 2d | 2016-02-29 | 2016-03-01 | 19FS+8d | 276d | 9d |  | Industry |  |
| 22 | 1.2.5 | **Work Pkg 1b** |  | 65d | 2015-12-09 | 2016-03-14 |  | 267d |  |  |  |  |
| 23 | 1.2.5.1 | Produce workshop #2 material - Work Pkg 1b |  | 5d | 2015-12-09 | 2015-12-15 | 6FS+8d | 267d | 0d |  | AEMO |  |
| 24 | 1.2.5.2 | Send WG workshop #2 material - Work Pkg 1b |  | 1d | 2015-12-16 | 2015-12-16 | 23 | 267d | 0d |  | AEMO |  |
| 25 | 1.2.5.3 | WG workshop #2 - Work Pkg 1b |  | 2d | 2016-01-12 | 2016-01-13 | 24FS+15d | 267d | 0d |  | Industry | Allow extra time for holiday period |
| 26 | 1.2.5.4 | Develop draft procedure - Work Pkg 1b |  | 10d | 2016-01-14 | 2016-01-28 | 25 | 267d | 0d |  | AEMO |  |
| 27 | 1.2.5.5 | Send WG workshop #4 material - Work Pkg 1b |  | 1d | 2016-01-29 | 2016-01-29 | 26 | 267d | 0d |  | AEMO |  |
| 28 | 1.2.5.6 | WG workshop #4 - Work Pkg 1b |  | 2d | 2016-02-11 | 2016-02-12 | 27FS+8d | 267d | 0d |  | Industry |  |
| 29 | 1.2.5.7 | Update draft procedure #6 - Work Pkg 1b |  | 10d | 2016-02-15 | 2016-02-26 | 28 | 267d | 0d |  | AEMO |  |
| 30 | 1.2.5.8 | Send WG workshop #6 material - Work Pkg 1b |  | 1d | 2016-02-29 | 2016-02-29 | 29 | 267d | 0d |  | AEMO |  |
| 31 | 1.2.5.9 | WG workshop #6 - Work Pkg 1b |  | 2d | 2016-03-11 | 2016-03-14 | 30FS+8d | 267d | 0d |  | Industry |  |
| 32 | 1.2.5.10 | Procedure Development Work Pkg 1a & 1b - complete | milestone | 0d | 2016-03-14 | 2016-03-14 | 31 | 712d |  |  |  |  |

Notes:
- 1: Workshops are not yet aligned with 2016 Industry Meeting calendar. / Time allowed for IEC approval will not be required if the IEC decides there are B2B changes. / Dates shown in grey are indicative dates.

| ID | WBS | Task | Type | Duration | Start | Finish | Predecessors | Total slack | Free slack | Responsibility |
| --- | --- | --- | --- | --- | --- | --- | --- | --- | --- | --- |
| 33 | 1.2.6 | **Consult'n - Work Pkg 1a & 1b** |  | 119d | 2016-03-15 | 2016-09-01 |  | 267d |  |  |
| 34 | 1.2.6.1 | **Initial consultation** |  | 53d | 2016-03-15 | 2016-05-31 |  | 267d |  |  |
| 35 | 1.2.6.1.1 | Prepare consultation material |  | 15d | 2016-03-15 | 2016-04-06 | 31, 21 | 267d | 0d | AEMO |
| 36 | 1.2.6.1.2 | **Obtain IEC Approval for B2B procedures** |  | 6d | 2016-04-07 | 2016-04-14 |  | 267d |  |  |
| 37 | 1.2.6.1.2.1 | Issue consultation papers to IEC |  | 1d | 2016-04-07 | 2016-04-07 | 35 | 267d | 0d | AEMO |
| 38 | 1.2.6.1.2.2 | Obtain IEC approval for consultation |  | 5d | 2016-04-08 | 2016-04-14 | 37 | 267d | 0d | IEC |
| 39 | 1.2.6.1.3 | Commence first stage of consultation |  | 1d | 2016-04-22 | 2016-04-22 | 38FS+5d | 267d | 0d | AEMO |
| 40 | 1.2.6.1.4 | P - Notice of consultation Work Pkg 1a & 1b | milestone | 0d | 2016-04-22 | 2016-04-22 | 39 | 685d |  |  |
| 41 | 1.2.6.1.5 | WG workshop #7 |  | 1d | 2016-05-17 | 2016-05-17 | 39FS+15d | 657d |  | AEMO |
| 42 | 1.2.6.1.6 | Submissions - Work Pkg 1a & 1b |  | 25d | 2016-04-26 | 2016-05-30 | 39 | 267d | 0d | Industry |
| 43 | 1.2.6.1.7 | First stage of consultation closed |  | 1d | 2016-05-31 | 2016-05-31 | 42 | 267d | 0d | AEMO |
| 44 | 1.2.6.2 | **Draft Determination** |  | 34d | 2016-06-01 | 2016-07-19 |  | 267d |  |  |
| 45 | 1.2.6.2.1 | Develop Draft Determination |  | 14d | 2016-06-01 | 2016-06-21 | 43 | 267d | 0d | AEMO |
| 46 | 1.2.6.2.2 | **Obtain IEC Approval for B2B procedures** |  | 6d | 2016-06-22 | 2016-06-29 |  | 267d |  |  |
| 47 | 1.2.6.2.2.1 | Issue Draft Determination to IEC |  | 1d | 2016-06-22 | 2016-06-22 | 45 | 267d | 0d | AEMO |
| 48 | 1.2.6.2.2.2 | Obtain IEC approval for consultation |  | 5d | 2016-06-23 | 2016-06-29 | 47 | 267d | 0d | IEC |
| 49 | 1.2.6.2.3 | Commence second stage of consultation |  | 1d | 2016-07-04 | 2016-07-04 | 48FS+2d | 267d | 0d | AEMO |
| 50 | 1.2.6.2.4 | P - Draft Determination Work Pkg 1a & 1b | milestone | 0d | 2016-07-04 | 2016-07-04 | 49 | 636d |  |  |
| 51 | 1.2.6.2.5 | Draft Determination submissions |  | 10d | 2016-07-05 | 2016-07-18 | 49 | 267d | 0d | Industry |
| 52 | 1.2.6.2.6 | Second stage of consultation closed |  | 1d | 2016-07-19 | 2016-07-19 | 51 | 267d | 0d | AEMO |
| 53 | 1.2.6.3 | **Final Determination** |  | 32d | 2016-07-20 | 2016-09-01 | 51 | 267d |  |  |
| 54 | 1.2.6.3.1 | Develop Final Determination |  | 23d | 2016-07-20 | 2016-08-19 | 52 | 267d | 0d | AEMO |
| 55 | 1.2.6.3.2 | **Obtain IEC Approval for B2B procedures** |  | 6d | 2016-08-22 | 2016-08-29 |  | 267d |  |  |
| 56 | 1.2.6.3.2.1 | Issue Final Determination to IEC |  | 1d | 2016-08-22 | 2016-08-22 | 54 | 267d | 0d | AEMO |
| 57 | 1.2.6.3.2.2 | Obtain IEC approval for consultation |  | 5d | 2016-08-23 | 2016-08-29 | 56 | 267d | 0d | IEC |
| 58 | 1.2.6.3.3 | Publish Final Determination |  | 1d | 2016-09-01 | 2016-09-01 | 57FS+2d | 279d | 0d | AEMO |
| 59 | 1.2.6.3.4 | P - Final Determination - Work Pkg 1a & 1b | milestone | 0d | 2016-09-01 | 2016-09-01 | 58 | 593d |  |  |

Notes:
- 41: Text Note: Allow time for participants to review consultation material prior to workshop
- 49: Text Note: Obtain IEC approval 2 days before consultation

| ID | WBS | Task | Type | Duration | Start | Finish | Predecessors | Total slack | Free slack | Responsibility |
| --- | --- | --- | --- | --- | --- | --- | --- | --- | --- | --- |
| 60 | 1.2.7 | **Work Pkg 2** |  | 102d | 2016-07-08 | 2016-11-28 |  | 267d |  |  |
| 61 | 1.2.7.1 | Produce workshop #8 material - Work Pkg 2 |  | 10d | 2016-07-08 | 2016-07-21 | 6FS+152d | 279d | 0d | AEMO |
| 62 | 1.2.7.2 | Send WG workshop #8 material - Work Pkg 2 |  | 1d | 2016-07-22 | 2016-07-22 | 61 | 279d | 0d | AEMO |
| 63 | 1.2.7.3 | WG workshop #8 - Work Pkg 2 |  | 2d | 2016-08-08 | 2016-08-09 | 62FS+10d | 279d | 0d | Industry |
| 64 | 1.2.7.4 | Produce workshop #9 material - Work Pkg 2 |  | 10d | 2016-08-10 | 2016-08-23 | 63 | 279d | 0d | AEMO |
| 65 | 1.2.7.5 | Send WG workshop #9 material - Work Pkg 2 |  | 1d | 2016-08-24 | 2016-08-24 | 64 | 279d | 0d | AEMO |
| 66 | 1.2.7.6 | WG workshop #9 - Work Pkg 2 |  | 2d | 2016-09-08 | 2016-09-09 | 65FS+10d | 279d | 0d | Industry |
| 67 | 1.2.7.7 | Develop draft procedure #10 - Work Pkg 2 |  | 10d | 2016-09-12 | 2016-09-23 | 66 | 279d | 0d | AEMO |
| 68 | 1.2.7.8 | Send WG workshop #10 material - Work Pkg 2 |  | 1d | 2016-09-26 | 2016-09-26 | 67 | 279d | 0d | AEMO |
| 69 | 1.2.7.9 | WG workshop #10 - Work Pkg 2 |  | 2d | 2016-10-11 | 2016-10-12 | 68FS+10d | 279d | 0d | Industry |
| 70 | 1.2.7.10 | Develop draft procedure #11 - Work Pkg 2 |  | 20d | 2016-10-13 | 2016-11-09 | 69 | 279d | 0d | AEMO |
| 71 | 1.2.7.11 | Send WG workshop #11 material - Work Pkg 2 |  | 1d | 2016-11-10 | 2016-11-10 | 70 | 279d | 0d | AEMO |
| 72 | 1.2.7.12 | WG workshop #11 - Work Pkg 2 |  | 2d | 2016-11-25 | 2016-11-28 | 71FS+10d | 279d | 0d | Industry |
| 73 | 1.2.8 | **Consult'n Work Pkg 2** |  | 100d | 2016-11-29 | 2017-04-26 |  | 267d |  |  |
| 74 | 1.2.8.1 | **Initial consultation** |  | 37d | 2016-11-29 | 2017-01-23 |  | 267d |  |  |
| 75 | 1.2.8.1.1 | Prepare consultation material |  | 10d | 2016-11-29 | 2016-12-12 | 72 | 279d | 0d | AEMO |
| 76 | 1.2.8.1.2 | Commence first stage of consultation |  | 1d | 2016-12-13 | 2016-12-13 | 75 | 279d | 0d | AEMO |
| 77 | 1.2.8.1.3 | P - Notice of consultation Work Pkg 2 | milestone | 0d | 2016-12-13 | 2016-12-13 | 76 | 520d |  |  |
| 78 | 1.2.8.1.4 | WG workshop #12 |  | 1d | 2017-01-09 | 2017-01-09 | 76FS+15d | 504d |  | Industry |
| 79 | 1.2.8.1.5 | Submissions - Work Pkg 2 |  | 25d | 2016-12-14 | 2017-01-20 | 76 | 279d | 0d | Industry |
| 80 | 1.2.8.1.6 | First stage of consultation closed |  | 1d | 2017-01-23 | 2017-01-23 | 79 | 279d | 0d | AEMO |
| 81 | 1.2.8.2 | **Draft Determination** |  | 32d | 2017-01-24 | 2017-03-09 |  | 267d |  |  |
| 82 | 1.2.8.2.1 | Develop Draft Determination |  | 20d | 2017-01-24 | 2017-02-21 | 80 | 279d | 0d | AEMO |
| 83 | 1.2.8.2.2 | Commence second stage of consultation |  | 1d | 2017-02-22 | 2017-02-22 | 82 | 279d | 0d | AEMO |
| 84 | 1.2.8.2.3 | P - Draft Determination Work Pkg 2 | milestone | 0d | 2017-02-22 | 2017-02-22 | 83 | 473d |  |  |
| 85 | 1.2.8.2.4 | Draft Determination submissions |  | 10d | 2017-02-23 | 2017-03-08 | 83 | 279d | 0d | Industry |
| 86 | 1.2.8.2.5 | Second stage of consultation closed |  | 1d | 2017-03-09 | 2017-03-09 | 85 | 279d | 0d | AEMO |

Notes:
- 61: Text Note: Work Pkg 2 starts when second consultation of first pkg begins
- 70: Text Note: Increased duration due to Christmas period
- 78: Text Note: Workshop 15 days after commencement of consultation

| ID | WBS | Task | Type | Duration | Start | Finish | Predecessors | Total slack | Free slack | Responsibility | Text Note |
| --- | --- | --- | --- | --- | --- | --- | --- | --- | --- | --- | --- |
| 87 | 1.2.8.3 | **Final Determination** |  | 31d | 2017-03-10 | 2017-04-26 | 85 | 267d |  |  |  |
| 88 | 1.2.8.3.1 | Develop Final Determination |  | 30d | 2017-03-10 | 2017-04-24 | 86 | 279d | 0d | AEMO |  |
| 89 | 1.2.8.3.2 | Publish Final Determination |  | 1d | 2017-04-26 | 2017-04-26 | 88 | 279d | 0d | AEMO |  |
| 90 | 1.2.8.3.3 | P - Final Determination - Work Pkg 2 | milestone | 0d | 2017-04-26 | 2017-04-26 | 89 | 431d |  |  |  |
| 91 | 1.2.9 | **Work Pkg 3** |  | 92d | 2017-02-24 | 2017-07-13 |  | 267d |  |  |  |
| 92 | 1.2.9.1 | Produce workshop #13 material - Work Pkg 3 |  | 10d | 2017-02-24 | 2017-03-09 | 6FS+313d | 267d | 0d | AEMO |  |
| 93 | 1.2.9.2 | Send WG workshop #13 material - Work Pkg 3 |  | 1d | 2017-03-10 | 2017-03-10 | 92 | 267d | 0d | AEMO |  |
| 94 | 1.2.9.3 | WG workshop #13 - Work Pkg 3 |  | 2d | 2017-03-27 | 2017-03-28 | 93FS+10d | 267d | 0d | Industry |  |
| 95 | 1.2.9.4 | Produce workshop #14 material - Work Pkg 3 |  | 10d | 2017-03-29 | 2017-04-11 | 94 | 267d | 0d | AEMO |  |
| 96 | 1.2.9.5 | Send WG workshop #14 material - Work Pkg 3 |  | 1d | 2017-04-12 | 2017-04-12 | 95 | 267d | 0d | AEMO |  |
| 97 | 1.2.9.6 | WG workshop #14 - Work Pkg 3 |  | 2d | 2017-05-02 | 2017-05-03 | 96FS+10d | 267d | 0d | Industry |  |
| 98 | 1.2.9.7 | Develop draft procedure # 15 - Work Pkg 3 |  | 10d | 2017-05-04 | 2017-05-17 | 97 | 267d | 0d | AEMO |  |
| 99 | 1.2.9.8 | Send WG workshop #15 material - Work Pkg 3 |  | 1d | 2017-05-18 | 2017-05-18 | 98 | 267d | 0d | AEMO |  |
| 100 | 1.2.9.9 | WG workshop #15 - Work Pkg 3 |  | 2d | 2017-06-02 | 2017-06-05 | 99FS+10d | 267d | 0d | Industry |  |
| 101 | 1.2.9.10 | Develop draft procedure # 16 - Work Pkg 3 |  | 10d | 2017-06-06 | 2017-06-26 | 100 | 267d | 0d | AEMO |  |
| 102 | 1.2.9.11 | Send WG workshop #16 material - Work Pkg 3 |  | 1d | 2017-06-27 | 2017-06-27 | 101 | 267d | 0d | AEMO |  |
| 103 | 1.2.9.12 | WG workshop #16 - Work Pkg 3 |  | 2d | 2017-07-12 | 2017-07-13 | 102FS+10d | 267d | 0d | Industry |  |
| 104 | 1.2.10 | **Consult'n - Work Pkg 3** |  | 100d | 2017-07-14 | 2017-11-30 |  | 267d |  |  |  |
| 105 | 1.2.10.1 | **Initial consultation** |  | 37d | 2017-07-14 | 2017-09-04 |  | 267d |  |  |  |
| 106 | 1.2.10.1.1 | Prepare consultation material |  | 10d | 2017-07-14 | 2017-07-27 | 103 | 267d | 0d | AEMO |  |
| 107 | 1.2.10.1.2 | Commence first stage of consultation |  | 1d | 2017-07-28 | 2017-07-28 | 106 | 267d | 0d | AEMO |  |
| 108 | 1.2.10.1.3 | P - Notice of consultation Work Pkg 3 | milestone | 0d | 2017-07-28 | 2017-07-28 | 107 | 369d |  |  |  |
| 109 | 1.2.10.1.4 | WG workshop #17 |  | 1d | 2017-08-21 | 2017-08-21 | 107FS+15d | 341d |  | Industry | workshop 15 days after commencement of consultation |
| 110 | 1.2.10.1.5 | Submissions - Work Pkg 3 |  | 25d | 2017-07-31 | 2017-09-01 | 107 | 267d | 0d | Industry |  |
| 111 | 1.2.10.1.6 | First stage of consultation closed |  | 1d | 2017-09-04 | 2017-09-04 | 110 | 267d | 0d | AEMO |  |

| ID | WBS | Task | Type | Duration | Start | Finish | Predecessors | Total slack | Free slack | Responsibility |
| --- | --- | --- | --- | --- | --- | --- | --- | --- | --- | --- |
| 112 | 1.2.10.2 | **Draft Determination** |  | 32d | 2017-09-05 | 2017-10-18 |  | 267d |  |  |
| 113 | 1.2.10.2.1 | Develop Draft Determination |  | 20d | 2017-09-05 | 2017-10-02 | 111 | 267d | 0d | AEMO |
| 114 | 1.2.10.2.2 | Commence second stage of consultation |  | 1d | 2017-10-03 | 2017-10-03 | 113 | 267d | 0d | AEMO |
| 115 | 1.2.10.2.3 | P - Draft Determination Work Pkg 3 | milestone | 0d | 2017-10-03 | 2017-10-03 | 114 | 322d |  |  |
| 116 | 1.2.10.2.4 | Draft Determination submissions |  | 10d | 2017-10-04 | 2017-10-17 | 114 | 267d | 0d | Industry |
| 117 | 1.2.10.2.5 | Second stage of consultation closed |  | 1d | 2017-10-18 | 2017-10-18 | 116 | 267d | 0d | AEMO |
| 118 | 1.2.10.3 | **Final Determination** |  | 31d | 2017-10-19 | 2017-11-30 | 116 | 267d |  |  |
| 119 | 1.2.10.3.1 | Develop Final Determination |  | 30d | 2017-10-19 | 2017-11-29 | 117 | 267d | 0d | AEMO |
| 120 | 1.2.10.3.2 | Publish Final Determination |  | 1d | 2017-11-30 | 2017-11-30 | 119 | 267d | 0d | AEMO |
| 121 | 1.2.10.3.3 | P - Final Determination - Work Pkg 3 | milestone | 0d | 2017-11-30 | 2017-11-30 | 120 | 280d |  |  |
| 122 | 1.3 | **Distribution ring fencing guideline (MC)** |  | 253d | 2015-11-27 | 2016-11-25 |  | 520d |  |  |
| 123 | 1.3.1 | Develop Distribution fencing guideline |  | 253d | 2015-11-27 | 2016-11-25 | 6 | 520d |  | AER |
| 124 | 1.4 | **System change (MC)** |  | 356d | 2016-07-04 | 2017-11-30 |  | 268d |  |  |
| 125 | 1.4.1 | **System Development** |  | 356d | 2016-07-04 | 2017-11-30 |  | 268d |  |  |
| 126 | 1.4.1.1 | Write aseXML Change Request submission |  | 46d | 2016-09-02 | 2016-11-04 | 58 | 493d | 0d | AEMO |
| 127 | 1.4.1.2 | Submit aseXML Change Request to ASWG |  | 1d | 2016-11-07 | 2016-11-07 | 126 | 493d | 0d | AEMO |
| 128 | 1.4.1.3 | ASWG review of draft schema |  | 18d | 2016-11-08 | 2016-12-01 | 127 | 493d | 0d | ASWG |
| 129 | 1.4.1.4 | Participant system development |  | 313d | 2016-09-02 | 2017-11-30 | 58 | 267d | 0d | Industry |
| 130 | 1.4.1.5 | Draft schema released |  | 1d | 2016-12-02 | 2016-12-02 | 128 | 493d | 0d | ASWG |
| 131 | 1.4.1.6 | ASWG prepare final schema |  | 19d | 2016-12-05 | 2017-01-03 | 130 | 493d | 0d | ASWG |
| 132 | 1.4.1.7 | Final aseXML schema released |  | 1d | 2017-01-04 | 2017-01-04 | 131 | 493d | 0d | ASWG |
| 133 | 1.4.1.8 | AEMO system development |  | 120d | 2016-09-02 | 2017-02-22 | 58 | 290d | 0d | AEMO |
| 134 | 1.4.1.9 | S- System change stage starts | milestone | 0d | 2016-07-04 | 2016-07-04 | 49 | 636d |  |  |
| 135 | 1.4.1.10 | AEMO change notice published |  | 1d | 2017-01-05 | 2017-01-05 | 132 | 493d | 0d | AEMO |
| 136 | 1.4.1.11 | Update technical document & publish |  | 1d | 2017-01-06 | 2017-01-06 | 135 | 493d |  | AEMO |

Notes:
- 127: Text Note: Submit by specific date prior to meeting
- 129: Text Note: starts at final determination of procedure work pkg 1
- 133: Text Note: starts 130 days after final determination of procedure work pkg 1 to reflect correct duration and aligned with release cycle

| ID | WBS | Task | Type | Duration | Start | Finish | Predecessors | Total slack | Free slack | Constraint | Responsibility |
| --- | --- | --- | --- | --- | --- | --- | --- | --- | --- | --- | --- |
| 137 | 1.4.2 | **System Implementation** |  | 171d | 2017-03-09 | 2017-11-15 |  | 279d |  |  |  |
| 138 | 1.4.2.1 | Pre-production |  | 41d | 2017-09-19 | 2017-11-14 | 133FS+140d | 290d | 0d |  | AEMO |
| 139 | 1.4.2.2 | S - Pre-production period starts | milestone | 0d | 2017-03-09 | 2017-03-09 | 133FS+11d | 462d |  |  |  |
| 140 | 1.4.2.3 | Production |  | 1d | 2017-11-15 | 2017-11-15 | 138 | 290d | 0d |  | AEMO |
| 141 | 1.4.2.4 | S - System change phase ends | milestone | 0d | 2017-11-15 | 2017-11-15 | 140 | 291d |  |  |  |
| 142 | 1.5 | **Market Readiness (MC)** |  | 151d | 2017-04-26 | 2017-11-30 |  | 267d |  |  |  |
| 143 | 1.5.1 | M - Registration & Accreditation activities start | milestone | 0d | 2017-04-26 | 2017-04-26 | 89 | 431d |  |  |  |
| 144 | 1.5.2 | Registration & transitional (AMI meters) activities |  | 151d | 2017-04-27 | 2017-11-30 | 89 | 279d | 0d |  | AEMO |
| 145 | 1.5.3 | M - Readiness activities completed | milestone | 0d | 2017-11-30 | 2017-11-30 | 144 | 280d |  |  |  |
| 146 | 1.5.4 | Accreditation activities |  | 151d | 2017-04-27 | 2017-11-30 | 89 | 279d | 0d |  | AEMO |
| 147 | 1.6 | GO LIVE (MC) |  | 1d | 2017-12-01 | 2017-12-01 | 140, 120, 144, 138, 129, 146 | 267d |  |  |  |
| 148 | 2 | **Embedded Networks (EN)** |  | 641d | 2015-05-21 | 2017-12-01 |  | 267d |  |  |  |
| 149 | 2.1 | **Rule Change (EN)** |  | 130d | 2015-05-21 | 2015-11-19 |  | 267d |  |  |  |
| 150 | 2.1.1 | R - Notice of consultation | milestone | 0d | 2015-05-21 | 2015-05-21 |  | 279d | 0d | start no earlier than 2015-05-21 | AEMC |
| 151 | 2.1.2 | Consultation submissions |  | 30d | 2015-05-21 | 2015-07-02 | 150 | 279d | 0d |  | Industry |
| 152 | 2.1.3 | Draft Determination |  | 50d | 2015-07-03 | 2015-09-10 | 151 | 279d | 0d |  | AEMC |
| 153 | 2.1.4 | R - Draft Determination | milestone | 0d | 2015-09-10 | 2015-09-10 | 152 | 840d |  |  |  |
| 154 | 2.1.5 | Consultation submissions |  | 30d | 2015-09-11 | 2015-10-22 | 152 | 279d | 0d |  | Industry |
| 155 | 2.1.6 | Final Determination |  | 20d | 2015-10-23 | 2015-11-19 | 154 | 279d | 0d |  | AEMC |
| 156 | 2.1.7 | R - Final Determination | milestone | 0d | 2015-11-19 | 2015-11-19 | 155 | 790d |  |  |  |
| 157 | 2.2 | **Procedure Change (EN)** |  | 423d | 2015-11-20 | 2017-08-01 |  | 271d |  |  |  |
| 158 | 2.2.1 | **Work Pkg 1 (EN)** |  | 73d | 2015-11-20 | 2016-03-07 |  | 271d |  |  |  |
| 159 | 2.2.1.1 | Procedure development Pkg 1 |  | 62d | 2015-11-20 | 2016-02-19 | 155 | 728d |  |  | AEMO |
| 160 | 2.2.1.2 | Produce workshop #1 material - Work Pkg 1 |  | 5d | 2015-11-20 | 2015-11-26 | 155 | 283d | 0d |  | AEMO |
| 161 | 2.2.1.3 | Send WG workshop #1 material - Work Pkg 1 |  | 1d | 2015-11-27 | 2015-11-27 | 160 | 283d | 0d | start no earlier than 2015-07-08 | AEMO |
| 162 | 2.2.1.4 | WG workshop #1 - Work Pkg 1 |  | 2d | 2015-12-14 | 2015-12-15 | 161FS+10d | 283d | 0d |  | Industry |
| 163 | 2.2.1.5 | Develop draft procedure #2 - Work Pkg 1 |  | 20d | 2015-12-16 | 2016-01-15 | 162 | 283d | 0d |  | AEMO |
| 164 | 2.2.1.6 | Send WG workshop #2 material - Work Pkg 1 |  | 1d | 2016-01-18 | 2016-01-18 | 163 | 283d | 0d |  | AEMO |
| 165 | 2.2.1.7 | WG workshop #2 - Work Pkg 1 |  | 2d | 2016-02-03 | 2016-02-04 | 164FS+10d | 283d | 0d |  | Industry |
| 166 | 2.2.1.8 | Update draft procedure #3 - Work Pkg 1 |  | 10d | 2016-02-05 | 2016-02-18 | 165 | 283d | 0d |  | AEMO |
| 167 | 2.2.1.9 | Send WG workshop #3 material - Work Pkg 1 |  | 1d | 2016-02-19 | 2016-02-19 | 166 | 728d |  |  |  |
| 168 | 2.2.1.10 | WG workshop #3 - Work Pkg 1 |  | 2d | 2016-03-04 | 2016-03-07 | 166FS+10d | 283d | 0d |  | Industry |

Notes:
- 138: Text Note: Pre prod 10 days after development to allow for internal verification
- 140: Text Note: Production approx. 2 weeks prior to go live
- 163: Text Note: Increased duration due to Christmas period

| ID | WBS | Task | Type | Duration | Start | Finish | Predecessors | Total slack | Free slack | Responsibility | Text Note |
| --- | --- | --- | --- | --- | --- | --- | --- | --- | --- | --- | --- |
| 169 | 2.2.2 | **Consult'n (EN) - Work Pkg 1** |  | 124d | 2016-03-08 | 2016-09-01 |  | 271d |  |  |  |
| 170 | 2.2.2.1 | **Initial consultation** |  | 60d | 2016-03-08 | 2016-06-02 |  | 271d |  |  |  |
| 171 | 2.2.2.1.1 | Prepare consultation material |  | 17d | 2016-03-08 | 2016-04-01 | 168 | 283d | 0d | AEMO |  |
| 172 | 2.2.2.1.2 | **Obtain IEC Approval for B2B procedures** |  | 11d | 2016-04-04 | 2016-04-18 |  | 271d |  |  |  |
| 173 | 2.2.2.1.2.1 | Issue consultation papers to IEC |  | 1d | 2016-04-04 | 2016-04-04 | 171 | 283d | 0d | AEMO |  |
| 174 | 2.2.2.1.2.2 | Obtain IEC approval for consultation |  | 10d | 2016-04-05 | 2016-04-18 | 173 | 283d | 0d | IEC |  |
| 175 | 2.2.2.1.3 | Commence first stage of consultation |  | 1d | 2016-04-27 | 2016-04-27 | 174FS+5d | 283d | 0d | AEMO | Obtain IEC approval 5 days before consultation |
| 176 | 2.2.2.1.4 | P - Notice of consultation Work Pkg 1 | milestone | 0d | 2016-04-27 | 2016-04-27 | 175 | 683d |  |  |  |
| 177 | 2.2.2.1.5 | WG workshop #4 |  | 1d | 2016-05-19 | 2016-05-19 | 175FS+15d | 667d |  | AEMO | workshop 15 days after commencement of consultation |
| 178 | 2.2.2.1.6 | Submissions - Work Pkg 1 |  | 25d | 2016-04-28 | 2016-06-01 | 175 | 283d | 0d | Industry |  |
| 179 | 2.2.2.1.7 | First stage of consultation closed |  | 1d | 2016-06-02 | 2016-06-02 | 178 | 283d | 0d | AEMO |  |
| 180 | 2.2.2.2 | **Draft Determination** |  | 34d | 2016-06-03 | 2016-07-21 |  | 271d |  |  |  |
| 181 | 2.2.2.2.1 | Develop Draft Determination |  | 15d | 2016-06-03 | 2016-06-24 | 179 | 283d | 0d | AEMO |  |
| 182 | 2.2.2.2.2 | **Obtain IEC Approval for B2B procedures** |  | 6d | 2016-06-27 | 2016-07-04 |  | 271d |  |  |  |
| 183 | 2.2.2.2.2.1 | Issue Draft Determination to IEC |  | 1d | 2016-06-27 | 2016-06-27 | 181 | 283d | 0d | AEMO |  |
| 184 | 2.2.2.2.2.2 | Obtain IEC approval for consultation |  | 5d | 2016-06-28 | 2016-07-04 | 183 | 283d | 0d | IEC |  |
| 185 | 2.2.2.2.3 | Commence second stage of consultation |  | 1d | 2016-07-06 | 2016-07-06 | 184FS+1d | 283d | 0d | AEMO | Obtain IEC approval 5 days before consultation |
| 186 | 2.2.2.2.4 | P - Draft Determination Work Pkg 1 | milestone | 0d | 2016-07-06 | 2016-07-06 | 185 | 634d |  |  |  |
| 187 | 2.2.2.2.5 | Draft Determination submissions |  | 10d | 2016-07-07 | 2016-07-20 | 185 | 283d | 0d | Industry |  |
| 188 | 2.2.2.2.6 | Second stage of consultation closed |  | 1d | 2016-07-21 | 2016-07-21 | 187 | 283d | 0d |  |  |
| 189 | 2.2.2.3 | **Final Determination** |  | 30d | 2016-07-22 | 2016-09-01 | 187 | 271d |  |  |  |
| 190 | 2.2.2.3.1 | Develop Final Determination |  | 16d | 2016-07-22 | 2016-08-12 | 188 | 283d | 0d | AEMO |  |
| 191 | 2.2.2.3.2 | **Obtain IEC Approval for B2B procedures** |  | 8d | 2016-08-15 | 2016-08-24 |  | 271d |  |  |  |
| 192 | 2.2.2.3.2.1 | Issue Final Determination to IEC |  | 1d | 2016-08-15 | 2016-08-15 | 190 | 283d | 0d | AEMO |  |
| 193 | 2.2.2.3.2.2 | Obtain IEC approval for consultation |  | 7d | 2016-08-16 | 2016-08-24 | 192 | 283d | 0d | IEC |  |
| 194 | 2.2.2.3.3 | Publish Final Determination |  | 1d | 2016-09-01 | 2016-09-01 | 193FS+5d | 283d | 0d | AEMO |  |
| 195 | 2.2.2.3.4 | P - Final Determination - Work Pkg 1 | milestone | 0d | 2016-09-01 | 2016-09-01 | 194 | 593d |  |  |  |

| ID | WBS | Task | Type | Duration | Start | Finish | Predecessors | Total slack | Free slack | Responsibility | Text Note |
| --- | --- | --- | --- | --- | --- | --- | --- | --- | --- | --- | --- |
| 196 | 2.2.3 | **Work Pkg 2 (EN)** |  | 98d | 2016-09-14 | 2017-02-02 |  | 267d |  |  |  |
| 197 | 2.2.3.1 | Produce workshop #5 material - Work Pkg 2 |  | 10d | 2016-09-14 | 2016-09-27 | 155FS+205d | 279d | 0d | AEMO |  |
| 198 | 2.2.3.2 | Send WG workshop #5 material - Work Pkg 2 |  | 1d | 2016-09-28 | 2016-09-28 | 197 | 279d | 0d | AEMO |  |
| 199 | 2.2.3.3 | WG workshop #5 - Work Pkg 2 |  | 1d | 2016-10-13 | 2016-10-13 | 198FS+10d | 279d | 0d | Industry |  |
| 200 | 2.2.3.4 | Produce workshop #6 material - Work Pkg 2 |  | 10d | 2016-10-14 | 2016-10-27 | 199 | 279d | 0d | AEMO |  |
| 201 | 2.2.3.5 | Send WG workshop #6 material - Work Pkg 2 |  | 1d | 2016-10-28 | 2016-10-28 | 200 | 279d | 0d | AEMO |  |
| 202 | 2.2.3.6 | WG workshop #6 - Work Pkg 2 |  | 1d | 2016-11-14 | 2016-11-14 | 201FS+10d | 279d | 0d | Industry |  |
| 203 | 2.2.3.7 | Update draft procedure #7 - Work Pkg 2 |  | 10d | 2016-11-15 | 2016-11-28 | 202 | 279d | 0d | AEMO |  |
| 204 | 2.2.3.8 | Send WG workshop #7 material - Work Pkg 2 |  | 1d | 2016-11-29 | 2016-11-29 | 203 | 279d | 0d | AEMO |  |
| 205 | 2.2.3.9 | WG workshop #7 - Work Pkg 2 |  | 1d | 2016-12-14 | 2016-12-14 | 204FS+10d | 279d | 0d | Industry |  |
| 206 | 2.2.3.10 | Update draft procedure #8 - Work Pkg 2 |  | 20d | 2016-12-15 | 2017-01-16 | 205 | 279d | 0d | AEMO | Increased duration due to Christmas period |
| 207 | 2.2.3.11 | Send WG workshop #8 material - Work Pkg 2 |  | 1d | 2017-01-17 | 2017-01-17 | 206 | 279d | 0d | AEMO |  |
| 208 | 2.2.3.12 | WG workshop #8 - Work Pkg 2 |  | 1d | 2017-02-02 | 2017-02-02 | 207FS+10d | 279d | 0d | Industry |  |
| 209 | 2.2.4 | **Consult'n (EN) - Work Pkg 2** |  | 120d | 2017-02-03 | 2017-08-01 |  | 267d |  |  |  |
| 210 | 2.2.4.1 | Notice of consultation Pkg 2 |  | 20d | 2017-02-03 | 2017-03-02 | 208 | 279d | 0d | AEMO |  |
| 211 | 2.2.4.2 | **Initial consultation** |  | 37d | 2017-03-03 | 2017-04-27 |  | 267d |  |  |  |
| 212 | 2.2.4.2.1 | Prepare consultation material |  | 10d | 2017-03-03 | 2017-03-16 | 210 | 279d | 0d | AEMO |  |
| 213 | 2.2.4.2.2 | Commence first stage of consultation |  | 1d | 2017-03-17 | 2017-03-17 | 212 | 279d | 0d | AEMO |  |
| 214 | 2.2.4.2.3 | P - Notice of consultation Work Pkg 2 | milestone | 0d | 2017-03-17 | 2017-03-17 | 213 | 456d |  |  |  |
| 215 | 2.2.4.2.4 | WG workshop #9 |  | 1d | 2017-04-03 | 2017-04-03 | 213FS+10d | 445d |  | Industry | workshop 10 days after commencement of consultation |
| 216 | 2.2.4.2.5 | Submissions - Work Pkg 2 |  | 25d | 2017-03-20 | 2017-04-26 | 213 | 279d | 0d | Industry |  |
| 217 | 2.2.4.2.6 | First stage of consultation closed |  | 1d | 2017-04-27 | 2017-04-27 | 216 | 279d | 0d | AEMO |  |
| 218 | 2.2.4.3 | **Draft Determination** |  | 32d | 2017-04-28 | 2017-06-19 |  | 267d |  |  |  |
| 219 | 2.2.4.3.1 | Develop Draft Determination |  | 20d | 2017-04-28 | 2017-05-25 | 217 | 279d | 0d | AEMO |  |
| 220 | 2.2.4.3.2 | Commence second stage of consultation |  | 1d | 2017-05-26 | 2017-05-26 | 219 | 279d | 0d | AEMO |  |
| 221 | 2.2.4.3.3 | P - Draft Determination Work Pkg 2 | milestone | 0d | 2017-05-26 | 2017-05-26 | 220 | 409d |  |  |  |
| 222 | 2.2.4.3.4 | Draft Determination submissions |  | 10d | 2017-05-29 | 2017-06-09 | 220 | 354d | 0d | Industry |  |
| 223 | 2.2.4.3.5 | Second stage of consultation closed |  | 1d | 2017-06-19 | 2017-06-19 | 222 | 354d | 0d | AEMO |  |

| ID | WBS | Task | Type | Duration | Start | Finish | Predecessors | Total slack | Free slack | Responsibility |
| --- | --- | --- | --- | --- | --- | --- | --- | --- | --- | --- |
| 224 | 2.2.4.4 | **Final Determination** |  | 31d | 2017-06-20 | 2017-08-01 | 222 | 354d |  |  |
| 225 | 2.2.4.4.1 | Develop Final Determination |  | 30d | 2017-06-20 | 2017-07-31 | 223 | 354d | 0d | AEMO |
| 226 | 2.2.4.4.2 | Publish Final Determination |  | 1d | 2017-08-01 | 2017-08-01 | 225 | 366d | 0d | AEMO |
| 227 | 2.2.4.4.3 | P - Final Determination - Work Pkg 2 | milestone | 0d | 2017-08-01 | 2017-08-01 | 226 | 367d |  |  |
| 228 | 2.3 | **System Change (EN)** |  | 351d | 2016-07-06 | 2017-11-27 |  | 271d |  |  |
| 229 | 2.3.1 | **System Development** |  | 351d | 2016-07-06 | 2017-11-27 |  | 271d |  |  |
| 230 | 2.3.1.1 | Write aseXML Change Request submission |  | 46d | 2016-09-02 | 2016-11-04 | 194 | 347d | 0d | AEMO |
| 231 | 2.3.1.2 | Submit aseXML Change Request to ASWG |  | 1d | 2016-11-07 | 2016-11-07 | 230 | 347d | 0d | AEMO |
| 232 | 2.3.1.3 | ASWG review of draft schema |  | 18d | 2016-11-08 | 2016-12-01 | 231 | 347d | 0d | ASWG |
| 233 | 2.3.1.4 | Participant system development (EN) |  | 310d | 2016-09-02 | 2017-11-27 | 194 | 283d |  | Industry |
| 234 | 2.3.1.5 | Draft schema released |  | 1d | 2016-12-02 | 2016-12-02 | 232 | 347d | 0d | ASWG |
| 235 | 2.3.1.6 | ASWG prepare final schema |  | 19d | 2016-12-05 | 2017-01-03 | 234 | 347d | 0d | ASWG |
| 236 | 2.3.1.7 | Final aseXML schema released |  | 1d | 2017-01-04 | 2017-01-04 | 235 | 347d | 0d | ASWG |
| 237 | 2.3.1.8 | AEMO system development |  | 231d | 2016-07-07 | 2017-06-05 | 185 | 349d | 0d | AEMO |
| 238 | 2.3.1.9 | S- System change stage starts | milestone | 0d | 2016-07-06 | 2016-07-06 | 185 | 634d |  |  |
| 239 | 2.3.1.10 | AEMO change notice published |  | 1d | 2017-06-08 | 2017-06-08 | 236FS+106d | 347d | 0d | AEMO |
| 240 | 2.3.1.11 | Update technical document & publish |  | 1d | 2017-08-29 | 2017-08-29 | 239FS+52d | 347d |  | AEMO |
| 241 | 2.3.2 | **System Implementation** |  | 41d | 2017-06-28 | 2017-08-24 |  | 337d |  |  |
| 242 | 2.3.2.1 | Pre-production |  | 40d | 2017-06-29 | 2017-08-23 | 237FS+12d | 349d | 0d | AEMO |
| 243 | 2.3.2.2 | S - Pre-production period starts | milestone | 0d | 2017-06-28 | 2017-06-28 | 237FS+12d | 391d |  |  |
| 244 | 2.3.2.3 | Production |  | 1d | 2017-08-24 | 2017-08-24 | 242 | 349d | 0d | AEMO |
| 245 | 2.3.2.4 | S - System change phase ends | milestone | 0d | 2017-08-24 | 2017-08-24 | 244 | 350d |  |  |
| 246 | 2.4 | **Market Readiness (EN)** |  | 129d | 2017-05-29 | 2017-11-30 |  | 267d |  |  |
| 247 | 2.4.1 | Readiness Activities |  | 129d | 2017-05-29 | 2017-11-30 | 220 | 279d | 0d | AEMO |
| 248 | 2.4.2 | M - Market Registration & Accreditation starts | milestone | 0d | 2017-08-01 | 2017-08-01 | 226 | 367d |  |  |
| 249 | 2.4.3 | M - Market Readiness activities completed | milestone | 0d | 2017-11-30 | 2017-11-30 | 247 | 280d |  |  |
| 250 | 2.5 | GO LIVE (EN) |  | 1d | 2017-12-01 | 2017-12-01 | 247, 244, 226, 234 | 267d |  |  |

| ID | WBS | Task | Type | Duration | Start | Finish | Predecessors | Total slack | Free slack | Constraint | Responsibility | Text Note |
| --- | --- | --- | --- | --- | --- | --- | --- | --- | --- | --- | --- | --- |
| 251 | 3 | **Shared Market Protocols (SMP)** |  | 779d | 2015-11-03 | 2018-11-27 |  | 12d |  |  |  |  |
| 252 | 3.1 | **Rule Change (SMP)** |  | 122d | 2015-11-03 | 2016-04-29 |  | 12d |  |  |  |  |
| 253 | 3.1.1 | Notice of consultation |  | 20d | 2015-11-03 | 2015-11-30 |  | 13d | 0d | finish no earlier than 2015-11-30 | AEMC |  |
| 254 | 3.1.2 | R - Notice of consultation | milestone | 0d | 2015-11-30 | 2015-11-30 | 253 | 783d |  |  |  |  |
| 255 | 3.1.3 | Consultation submissions |  | 20d | 2015-12-01 | 2015-12-30 | 253 | 13d | 0d |  | Industry |  |
| 256 | 3.1.4 | Draft Determination |  | 41d | 2015-12-31 | 2016-02-29 | 255 | 13d | 0d |  | AEMC |  |
| 257 | 3.1.5 | R - Draft Determination | milestone | 0d | 2016-02-29 | 2016-02-29 | 256 | 722d |  |  |  |  |
| 258 | 3.1.6 | Consultation submissions (draft) |  | 30d | 2016-03-01 | 2016-04-13 | 256 | 13d | 0d |  | Industry |  |
| 259 | 3.1.7 | Final Determination |  | 11d | 2016-04-14 | 2016-04-29 | 258 | 13d | 0d |  | AEMC |  |
| 260 | 3.1.8 | R - Final Determination | milestone | 0d | 2016-04-29 | 2016-04-29 | 259 | 681d |  |  |  |  |
| 261 | 3.2 | **Procedure Change (SMP)** |  | 440d | 2016-05-02 | 2018-01-26 |  | 12d |  |  |  |  |
| 262 | 3.2.1 | **Procedure development (SMP) - Work Pkg 1** |  | 240d | 2016-05-02 | 2017-04-07 |  | 12d |  |  |  |  |
| 263 | 3.2.1.1 | Procedure development Pkg 1 |  | 240d | 2016-05-02 | 2017-04-07 | 259 | 13d | 0d |  | AEMO | Extended period for requirement analysis |
| 264 | 3.2.2 | **Procedure consultation (SMP) - Work Pkg 1** |  | 95d | 2017-04-10 | 2017-08-30 |  | 12d |  |  |  |  |
| 265 | 3.2.2.1 | Notice of consultation Pkg 1 |  | 10d | 2017-04-10 | 2017-04-26 | 263 | 13d | 0d |  | AEMO |  |
| 266 | 3.2.2.2 | Consultation submissions Pkg 1 |  | 25d | 2017-04-27 | 2017-05-31 | 265 | 13d | 0d |  | Industry |  |
| 267 | 3.2.2.3 | Draft determination Pkg 1 |  | 20d | 2017-06-01 | 2017-07-05 | 266 | 13d | 0d |  | AEMO |  |
| 268 | 3.2.2.4 | Consultation submission Pkg 1 (draft) |  | 10d | 2017-07-06 | 2017-07-19 | 267 | 13d | 0d |  | Industry |  |
| 269 | 3.2.2.5 | Final determination Pkg 1 |  | 30d | 2017-07-20 | 2017-08-30 | 268 | 13d | 0d |  | AEMO |  |
| 270 | 3.2.2.6 | P - Final Determination Work Pkg 1 | milestone | 0d | 2017-08-30 | 2017-08-30 | 269 | 346d |  |  |  |  |
| 271 | 3.2.3 | **Procedure development (SMP) - Work Pkg 2** |  | 40d | 2017-07-06 | 2017-08-30 |  | 12d |  |  | AEMO |  |
| 272 | 3.2.3.1 | Procedure development Pkg 2 |  | 40d | 2017-07-06 | 2017-08-30 | 267 | 39d | 0d |  | AEMO |  |
| 273 | 3.2.4 | **Procedure consultation (SMP) - Work Pkg 2** |  | 105d | 2017-08-31 | 2018-01-26 |  | 12d |  |  |  |  |
| 274 | 3.2.4.1 | Notice of consultation Pkg 2 |  | 20d | 2017-08-31 | 2017-09-27 | 272 | 39d | 0d |  | AEMO |  |
| 275 | 3.2.4.2 | Consultation submissions Pkg 2 |  | 25d | 2017-09-28 | 2017-11-01 | 274 | 39d | 0d |  | Industry |  |
| 276 | 3.2.4.3 | Draft determination Pkg 2 |  | 20d | 2017-11-02 | 2017-11-29 | 275 | 39d | 0d |  | AEMO |  |
| 277 | 3.2.4.4 | Consultation submissions Pkg 2 (draft) |  | 10d | 2017-11-30 | 2017-12-13 | 276 | 39d | 0d |  | Industry |  |
| 278 | 3.2.4.5 | Final determination Pkg 2 |  | 30d | 2017-12-14 | 2018-01-26 | 277 | 39d | 0d |  | AEMO |  |
| 279 | 3.2.4.6 | P - Final Determination Work Pkg 2 | milestone | 0d | 2018-01-26 | 2018-01-26 | 278 | 241d |  |  |  |  |

| ID | WBS | Task | Type | Duration | Start | Finish | Predecessors | Total slack | Free slack | Constraint | Responsibility | Text Note |
| --- | --- | --- | --- | --- | --- | --- | --- | --- | --- | --- | --- | --- |
| 280 | 3.3 | **System Change (SMP)** |  | 506d | 2016-11-28 | 2018-11-23 |  | 14d |  |  |  |  |
| 281 | 3.3.1 | Buildpack development |  | 90d | 2016-11-28 | 2017-04-06 | 258FS+160d | 442d |  |  | AEMO |  |
| 282 | 3.3.2 | Design, Build, Test |  | 300d | 2017-08-31 | 2018-10-26 | 269 | 13d | 0d |  | Industry |  |
| 283 | 3.3.3 | Design, Build, Test |  | 325d | 2017-07-06 | 2018-10-05 | 267 | 28d | 15d |  | AEMO |  |
| 284 | 3.3.4 | S - System change phase starts | milestone | 0d | 2017-07-05 | 2017-07-05 | 267 | 386d |  |  |  |  |
| 285 | 3.3.5 | Pre-production |  | 20d | 2018-10-29 | 2018-11-23 | 282, 283 | 13d | 0d |  |  |  |
| 286 | 3.3.6 | S - System change phase ends | milestone | 0d | 2018-10-26 | 2018-10-26 | 282 | 34d |  |  |  |  |
| 287 | 3.4 | **Market Readiness (SMP)** |  | 216d | 2018-01-26 | 2018-11-26 |  | 12d |  |  |  |  |
| 288 | 3.4.1 | Readiness Activities |  | 216d | 2018-01-29 | 2018-11-26 | 278 | 12d | 0d |  | AEMO |  |
| 289 | 3.4.2 | M - Market Readiness activities start | milestone | 0d | 2018-01-26 | 2018-01-26 | 278 | 241d |  |  |  |  |
| 290 | 3.4.3 | M - Market Readiness activities completed | milestone | 0d | 2018-11-26 | 2018-11-26 | 288 | 13d |  |  |  |  |
| 291 | 3.5 | GO LIVE (SMP) |  | 1d | 2018-11-27 | 2018-11-27 | 282, 278, 288, 285 | 12d |  |  |  |  |
| 292 | 4 | **Multiple Trading Relationships (MTR)** |  | 813d | 2015-06-29 | 2018-09-07 |  | 69d |  |  |  |  |
| 293 | 4.1 | **Rule Change (MTR)** |  | 322d | 2015-06-29 | 2016-09-30 |  | 76d |  |  |  |  |
| 294 | 4.1.1 | Notice of consultation |  | 25d | 2015-06-29 | 2015-07-31 |  | 88d | 0d | finish no earlier than 2015-07-31 | AEMC |  |
| 295 | 4.1.2 | R - Notice of consultation | milestone | 0d | 2015-07-31 | 2015-07-31 | 294 | 869d |  |  |  |  |
| 296 | 4.1.3 | Consultation submissions |  | 195d | 2015-08-03 | 2016-05-10 | 294 | 88d | 7d |  | Industry | Extended consultation period |
| 297 | 4.1.4 | Draft Determination |  | 50d | 2016-05-20 | 2016-07-29 | 296 | 69d | 0d | finish no earlier than 2016-07-29 | AEMC |  |
| 298 | 4.1.5 | R - Draft Determination | milestone | 0d | 2016-07-29 | 2016-07-29 | 297 | 617d |  |  |  |  |
| 299 | 4.1.6 | Consultation submissions (draft) |  | 30d | 2016-08-01 | 2016-09-09 | 297 | 81d | 0d |  | Industry |  |
| 300 | 4.1.7 | Final Determination |  | 15d | 2016-09-12 | 2016-09-30 | 299 | 81d | 0d |  | AEMC |  |
| 301 | 4.1.8 | R - Final Determination | milestone | 0d | 2016-09-30 | 2016-09-30 | 300 | 572d |  |  |  |  |
| 302 | 4.2 | **Procedure Change (MTR)** |  | 170d | 2016-10-03 | 2017-06-06 |  | 69d |  |  |  |  |
| 303 | 4.2.1 | Procedure development |  | 65d | 2016-10-03 | 2017-01-04 | 300 | 81d | 0d |  | AEMO |  |
| 304 | 4.2.2 | Notice of consultation |  | 20d | 2017-01-05 | 2017-02-02 | 303 | 81d | 0d |  | AEMO |  |
| 305 | 4.2.3 | Consultation submissions |  | 25d | 2017-02-03 | 2017-03-09 | 304 | 81d | 0d |  | Industry |  |
| 306 | 4.2.4 | Draft Determination |  | 20d | 2017-03-10 | 2017-04-06 | 305 | 81d | 0d |  | AEMO |  |
| 307 | 4.2.5 | Consultation submissions (draft) |  | 10d | 2017-04-07 | 2017-04-24 | 306 | 81d | 0d |  | Industry |  |
| 308 | 4.2.6 | Final Determination |  | 30d | 2017-04-26 | 2017-06-06 | 307 | 81d | 0d |  | AEMO |  |
| 309 | 4.2.7 | P - Final Determination | milestone | 0d | 2017-06-06 | 2017-06-06 | 308 | 402d |  |  |  |  |

| ID | WBS | Task | Type | Duration | Start | Finish | Predecessors | Total slack | Free slack | Constraint | Responsibility | Text Note |
| --- | --- | --- | --- | --- | --- | --- | --- | --- | --- | --- | --- | --- |
| 310 | 4.3 | **System Change (MTR)** |  | 360d | 2017-04-06 | 2018-09-06 |  | 69d |  |  |  |  |
| 311 | 4.3.1 | Design, Build, Test |  | 300d | 2017-06-07 | 2018-08-09 | 308 | 69d | 0d |  | Industry |  |
| 312 | 4.3.2 | Design, Build, Test |  | 340d | 2017-04-07 | 2018-08-09 | 306 | 81d | 0d |  | AEMO |  |
| 313 | 4.3.3 | S- System change phase starts | milestone | 0d | 2017-04-06 | 2017-04-06 | 306 | 442d |  |  |  |  |
| 314 | 4.3.4 | Pre-production |  | 20d | 2018-08-10 | 2018-09-06 | 311, 312 | 69d | 0d |  | AEMO |  |
| 315 | 4.3.5 | S - System change phase ends | milestone | 0d | 2018-09-06 | 2018-09-06 | 314 | 82d |  |  |  |  |
| 316 | 4.4 | **Market Readiness (MTR)** |  | 320d | 2017-06-06 | 2018-09-06 |  | 70d |  |  |  |  |
| 317 | 4.4.1 | Readiness Activities |  | 120d | 2018-03-23 | 2018-09-06 | 308FS+200d | 70d |  |  | AEMO |  |
| 318 | 4.4.2 | M - Market Readiness Activities start | milestone | 0d | 2017-06-06 | 2017-06-06 | 308 | 402d |  |  |  |  |
| 319 | 4.5 | GO LIVE (MTR) |  | 1d | 2018-09-07 | 2018-09-07 | 311, 314 | 69d |  |  |  |  |
| 320 | 5 | **Demand Response Mechanism (DRM)** |  | 791d | 2015-11-03 | 2018-12-13 |  | 0d |  |  |  |  |
| 321 | 5.1 | **Rule Change (DRM)** |  | 310d | 2015-11-03 | 2017-01-24 |  | 0d |  |  |  |  |
| 322 | 5.1.1 | Notice of consultation |  | 20d | 2015-11-03 | 2015-11-30 |  | 0d |  | finish no earlier than 2015-11-30 | AEMC |  |
| 323 | 5.1.2 | R - Notice of consultation | milestone | 0d | 2015-11-30 | 2015-11-30 | 322 | 783d |  |  |  |  |
| 324 | 5.1.3 | Consultation submissions |  | 190d | 2015-12-01 | 2016-09-01 | 322 | 0d |  |  | Industry | Extended rule consultation period |
| 325 | 5.1.4 | Draft Determination |  | 50d | 2016-09-02 | 2016-11-10 | 324 | 0d |  |  | AEMC |  |
| 326 | 5.1.5 | R - Draft Determination | milestone | 0d | 2016-11-10 | 2016-11-10 | 325 | 543d |  |  |  |  |
| 327 | 5.1.6 | Consultation submissions (draft) |  | 20d | 2016-11-11 | 2016-12-08 | 325 | 493d | 0d |  | Industry |  |
| 328 | 5.1.7 | Final Determination |  | 30d | 2016-12-09 | 2017-01-24 | 327 | 493d | 0d |  | AEMC |  |
| 329 | 5.1.8 | R - Final Determination | milestone | 0d | 2017-01-24 | 2017-01-24 | 328 | 493d |  |  |  |  |
| 330 | 5.2 | **Procedure Change (DRM)** |  | 185d | 2016-11-11 | 2017-08-14 |  | 0d |  |  |  |  |
| 331 | 5.2.1 | Procedure development |  | 80d | 2016-11-11 | 2017-03-08 | 325 | 0d |  |  | AEMO |  |
| 332 | 5.2.2 | Notice of consultation |  | 20d | 2017-03-09 | 2017-04-05 | 331 | 0d |  |  | AEMO |  |
| 333 | 5.2.3 | Consultation submissions |  | 25d | 2017-04-06 | 2017-05-15 | 332 | 0d |  |  | Industry |  |
| 334 | 5.2.4 | Draft Determination |  | 20d | 2017-05-16 | 2017-06-19 | 333 | 0d |  |  | AEMO |  |
| 335 | 5.2.5 | Consultation submissions (draft) |  | 10d | 2017-06-20 | 2017-07-03 | 334 | 0d |  |  | Industry |  |
| 336 | 5.2.6 | Final Determination |  | 30d | 2017-07-04 | 2017-08-14 | 335 | 0d |  |  | AEMO |  |
| 337 | 5.2.7 | P - Final Determination | milestone | 0d | 2017-08-14 | 2017-08-14 | 336 | 358d |  |  |  |  |

| ID | WBS | Task | Type | Duration | Start | Finish | Predecessors | Total slack | Free slack | Constraint | Responsibility |
| --- | --- | --- | --- | --- | --- | --- | --- | --- | --- | --- | --- |
| 338 | 5.3 | **System Change (DRM)** |  | 385d | 2017-06-19 | 2018-12-12 |  | 0d |  |  |  |
| 339 | 5.3.1 | Design, Build, Test |  | 300d | 2017-08-15 | 2018-10-10 | 336 | 5d |  |  | Industry |
| 340 | 5.3.2 | Design, Build, Test |  | 345d | 2017-06-20 | 2018-10-17 | 334 | 0d |  |  | AEMO |
| 341 | 5.3.3 | S - System change phase starts | milestone | 0d | 2017-06-19 | 2017-06-19 | 334 | 398d |  |  |  |
| 342 | 5.3.4 | Pre-production |  | 40d | 2018-10-18 | 2018-12-12 | 339, 340 | 0d |  |  |  |
| 343 | 5.3.5 | S - System change phase ends | milestone | 0d | 2018-10-17 | 2018-10-17 | 339, 340 | 53d |  |  |  |
| 344 | 5.4 | **Market Readiness (DRM)** |  | 180d | 2018-04-04 | 2018-12-12 |  | 0d |  |  |  |
| 345 | 5.4.1 | Readiness Activities |  | 180d | 2018-04-05 | 2018-12-12 | 336FS+165d | 0d |  |  | AEMO |
| 346 | 5.4.2 | M - Market Readiness Activities start | milestone | 0d | 2018-04-04 | 2018-04-04 | 336FS+165d | 181d |  |  |  |
| 347 | 5.5 | GO LIVE (DRM) |  | 1d | 2018-12-13 | 2018-12-13 | 339, 345, 340, 342 | 0d |  |  |  |
| 348 | 6 | **Meter Replacement Processes (MRP)** |  | 128d | 2015-05-21 | 2015-11-18 |  | 779d |  |  |  |
| 349 | 6.1 | **Rule Change (MRP)** |  | 128d | 2015-05-21 | 2015-11-18 |  | 779d |  |  |  |
| 350 | 6.1.1 | Notice of consultation | milestone | 0d | 2015-05-21 | 2015-05-21 |  | 791d | 0d | finish no earlier than 2015-05-21 | AEMC |
| 351 | 6.1.2 | Consultation submissions |  | 29d | 2015-05-22 | 2015-07-02 | 350 | 791d | 0d |  | Industry |
| 352 | 6.1.3 | Draft Determination |  | 36d | 2015-07-03 | 2015-08-21 | 351 | 791d | 0d |  | AEMC |
| 353 | 6.1.4 | Consultation submissions (draft) |  | 30d | 2015-08-24 | 2015-10-02 | 352 | 791d | 0d |  | Industry |
| 354 | 6.1.5 | Final Determination |  | 33d | 2015-10-05 | 2015-11-18 | 353 | 791d |  |  | AEMC |
| 355 | 7 | **NSW ACT Gas Retail Project (NAGRP)** |  | 230d | 2015-06-03 | 2016-04-29 |  | 669d |  |  |  |
| 356 | 7.1 | Project duration (NAGRP) |  | 230d | 2015-06-03 | 2016-04-29 |  | 716d |  | finish no earlier than 2016-04-29 |  |

Notes:
- 348: Non PoC project - potential risk to PoC project / Text Note: Non PoC project - potential risk to PoC project
- 355: Non PoC project - for noting as potential impact on PoC resources / Text Note: Non PoC project - for noting as potential impact on PoC resources
