# Metering Competition external 2

Schedule from MS Project, 2015-03-26 to 2019-03-19.
AEMO

## Calendars

- Standard: Mon-Fri 08:00-12:00, 13:00-17:00; Sat-Sun off. Exceptions (off unless hours are given): 2015-06-08 (Queen's Birthday 2015), 2015-12-25 (Christmas Day 2015), 2015-12-28 (Boxing Day 2015), 2016-01-01 (New Year's Day 2016), 2016-01-26 (Australia Day 2016), 2016-03-25 (Easter Friday 2016), 2016-03-28 (Easter Monday 2016), 2016-04-25 (ANZAC Day 2016), 2016-06-13 (Queen's Birthday 2016), 2016-12-26 (Christmas Day 2016), 2016-12-27 (Boxing Day 2016), 2017-01-02 (New Year's Day 2017), 2017-01-26 (Australia Day 2017), 2017-04-14 (Easter Friday), 2017-04-17 (Easter Monday 2017), 2017-04-25 (ANZAC Day 2017), 2017-06-12 to 2017-06-16 (Queen's Birthday 2017), 2017-12-25 (Christmas Day 2017), 2017-12-26 (Boxing Day 2017).

## Schedule

| ID | WBS | Task | Type | Duration | Start | Finish | Predecessors | Total slack | Free slack | Constraint | Responsibility | Text Note |
| --- | --- | --- | --- | --- | --- | --- | --- | --- | --- | --- | --- | --- |
| 1 | 1 | **Metering Competition (MC)** |  | 742d | 2015-03-26 | 2018-02-28 |  | 0d |  |  |  |  |
| 2 | 1.1 | **Rule Change (MC)** |  | 175d | 2015-03-26 | 2015-11-26 |  | 0d |  |  |  |  |
| 3 | 1.1.1 | Draft Determination |  | 1d | 2015-03-26 | 2015-03-26 |  | 0d |  | must finish on 2015-03-26 |  |  |
| 4 | 1.1.2 | R - Draft Determination | milestone | 0d | 2015-03-26 | 2015-03-26 | 3 | 994d |  |  |  |  |
| 5 | 1.1.3 | Consultation Submissions |  | 40d | 2015-03-27 | 2015-05-21 | 3 | 0d |  | must start on 2015-03-27 | AEMC |  |
| 6 | 1.1.4 | Final Determination |  | 116d | 2015-06-18 | 2015-11-26 | 5 | 253d | 0d | finish no earlier than 2015-11-26 | AEMC |  |
| 7 | 1.1.5 | MC Final Determination | milestone | 0d | 2015-11-26 | 2015-11-26 | 6 | 820d |  |  |  |  |
| 8 | 1.2 | **Procedure Change (MC)** |  | 687d | 2015-06-11 | 2018-02-27 |  | 254d |  |  |  |  |
| 9 | 1.2.1 | Initial workshop (BMRG) |  | 1d | 2015-06-11 | 2015-06-11 | 5FS+13d | 940d |  |  | AEMO |  |
| 10 | 1.2.2 | Initial workshop (MSWG) |  | 1d | 2015-06-25 | 2015-06-25 | 5FS+23d | 930d |  |  | AEMO |  |
| 11 | 1.2.3 | Initial workshop (MRG) |  | 1d | 2015-06-22 | 2015-06-22 | 5FS+20d | 933d |  |  | AEMO |  |
| 12 | 1.2.4 | **Work Pkg 1a** |  | 90d | 2015-11-27 | 2016-04-08 |  | 290d |  |  |  |  |
| 13 | 1.2.4.1 | Produce workshop #1 material - Work Pkg 1a |  | 5d | 2015-11-27 | 2015-12-03 | 6 | 269d | 0d |  | AEMO |  |
| 14 | 1.2.4.2 | Send WG workshop #1 material - Work Pkg 1a |  | 1d | 2015-12-04 | 2015-12-04 | 13 | 269d | 0d | start no earlier than 2015-07-08 | AEMO |  |
| 15 | 1.2.4.3 | WG workshop #1 - Work Pkg 1a |  | 2d | 2015-12-16 | 2015-12-17 | 14FS+7d | 269d | 0d |  | Industry |  |
| 16 | 1.2.4.4 | Develop draft procedure #3 - Work Pkg 1a |  | 18d | 2015-12-18 | 2016-01-15 | 15 | 269d | 0d |  | AEMO | Increased duration to allow for Christmas period |
| 17 | 1.2.4.5 | Send WG workshop #3 material - Work Pkg 1a |  | 1d | 2016-01-18 | 2016-01-18 | 16 | 269d | 0d |  | AEMO |  |
| 18 | 1.2.4.6 | WG workshop #3 - Work Pkg 1a |  | 2d | 2016-02-03 | 2016-02-04 | 17FS+10d | 269d | 0d |  | Industry |  |
| 19 | 1.2.4.7 | Update draft procedure #5 - Work Pkg 1a |  | 10d | 2016-02-05 | 2016-02-18 | 18 | 269d | 0d |  | AEMO |  |
| 20 | 1.2.4.8 | Send WG workshop #5 material - Work Pkg 1a |  | 1d | 2016-02-19 | 2016-02-19 | 19 | 763d |  |  |  |  |
| 21 | 1.2.4.9 | WG workshop #5 - Work Pkg 1a |  | 2d | 2016-03-04 | 2016-03-07 | 19FS+10d | 269d | 0d |  | Industry |  |
| 22 | 1.2.4.10 | Update draft procedure #7 - Work Pkg 1a |  | 10d | 2016-03-08 | 2016-03-21 | 21 | 269d | 0d |  | AEMO |  |
| 23 | 1.2.4.11 | Send WG workshop #7 material - Work Pkg 1a |  | 1d | 2016-03-22 | 2016-03-22 | 22 | 741d |  |  | AEMO |  |
| 24 | 1.2.4.12 | WG workshop #7 - Work Pkg 1a |  | 2d | 2016-04-07 | 2016-04-08 | 22FS+10d | 269d | 16d |  | Industry |  |

Notes:
- 1: Workshops not yet aligned to 2016 Industry Meeting calendar. / Time allowed for IEC approval will not be required if the IEC decides there are B2B changes. / Dates shown in grey are indicative dates.

| ID | WBS | Task | Type | Duration | Start | Finish | Predecessors | Total slack | Free slack | Responsibility | Text Note |
| --- | --- | --- | --- | --- | --- | --- | --- | --- | --- | --- | --- |
| 25 | 1.2.5 | **Work Pkg 1b** |  | 96d | 2015-12-11 | 2016-05-03 |  | 274d |  |  |  |
| 26 | 1.2.5.1 | Produce workshop #2 material - Work Pkg 1b |  | 6d | 2015-12-11 | 2015-12-18 | 6FS+10d | 253d | 0d | AEMO |  |
| 27 | 1.2.5.2 | Send WG workshop #2 material - Work Pkg 1b |  | 1d | 2015-12-21 | 2015-12-21 | 26 | 253d | 0d | AEMO |  |
| 28 | 1.2.5.3 | WG workshop #2 - Work Pkg 1b |  | 2d | 2016-01-20 | 2016-01-21 | 27FS+18d | 253d | 0d | Industry | Allow for Christmas |
| 29 | 1.2.5.4 | Develop draft procedure - Work Pkg 1b |  | 10d | 2016-01-22 | 2016-02-05 | 28 | 253d | 0d | AEMO |  |
| 30 | 1.2.5.5 | Send WG workshop #4 material - Work Pkg 1b |  | 1d | 2016-02-08 | 2016-02-08 | 29 | 253d | 0d | AEMO |  |
| 31 | 1.2.5.6 | WG workshop #4 - Work Pkg 1b |  | 2d | 2016-02-23 | 2016-02-24 | 30FS+10d | 253d | 0d | Industry |  |
| 32 | 1.2.5.7 | Update draft procedure #6 - Work Pkg 1b |  | 10d | 2016-02-25 | 2016-03-09 | 31 | 253d | 0d | AEMO |  |
| 33 | 1.2.5.8 | Send WG workshop #6 material - Work Pkg 1b |  | 1d | 2016-03-10 | 2016-03-10 | 32 | 253d | 0d | AEMO |  |
| 34 | 1.2.5.9 | WG workshop #6 - Work Pkg 1b |  | 2d | 2016-03-29 | 2016-03-30 | 33FS+10d | 253d | 0d | Industry |  |
| 35 | 1.2.5.10 | Update draft procedure #8 - Work Pkg 1b |  | 10d | 2016-03-31 | 2016-04-13 | 34 | 253d | 0d | AEMO |  |
| 36 | 1.2.5.11 | Send WG workshop #8 material - Work Pkg 1b |  | 1d | 2016-04-14 | 2016-04-14 | 35 | 253d | 0d | AEMO |  |
| 37 | 1.2.5.12 | WG workshop #8 - Work Pkg 1b |  | 2d | 2016-05-02 | 2016-05-03 | 36FS+10d | 253d | 0d | Industry |  |
| 38 | 1.2.5.13 | Procedure Development Work Pkg 1a & 1b - complete | milestone | 0d | 2016-05-03 | 2016-05-03 | 37 | 714d |  |  |  |
| 39 | 1.2.6 | **Consult'n - Pkg 1a & 1b** |  | 160d | 2016-05-04 | 2016-12-14 |  | 274d |  |  |  |
| 40 | 1.2.6.1 | **Initial consultation** |  | 69d | 2016-05-04 | 2016-08-09 |  | 274d |  |  |  |
| 41 | 1.2.6.1.1 | Prepare consultation material |  | 11d | 2016-05-04 | 2016-05-18 | 37, 24 | 253d | 0d | AEMO |  |
| 42 | 1.2.6.1.2 | **Obtain IEC Approval for B2B procedures** |  | 11d | 2016-05-19 | 2016-06-02 |  | 274d |  |  |  |
| 43 | 1.2.6.1.2.1 | Issue consultation papers to IEC |  | 1d | 2016-05-19 | 2016-05-19 | 41 | 253d | 0d | AEMO |  |
| 44 | 1.2.6.1.2.2 | Obtain IEC approval for consultation |  | 10d | 2016-05-20 | 2016-06-02 | 43 | 253d | 0d | IEC | Allow 10 days for IEC review of consultation material |
| 45 | 1.2.6.1.3 | Commence first stage of consultation |  | 1d | 2016-06-20 | 2016-06-20 | 44FS+10d | 253d | 0d | AEMO | Obtain IEC approval 10 days before consultation |
| 46 | 1.2.6.1.4 | P - Notice of consultation Work Pkg 1a & 1b | milestone | 0d | 2016-06-20 | 2016-06-20 | 45 | 681d |  |  |  |
| 47 | 1.2.6.1.5 | WG workshop #9 |  | 1d | 2016-07-12 | 2016-07-12 | 45FS+15d | 665d |  | AEMO | Workshop held 15 days after commencement of consultation |
| 48 | 1.2.6.1.6 | Submissions - Work Pkg 1a & 1b |  | 35d | 2016-06-21 | 2016-08-08 | 45 | 253d | 0d | Industry | Extended consultation period |
| 49 | 1.2.6.1.7 | First stage of consultation closed |  | 1d | 2016-08-09 | 2016-08-09 | 48 | 253d | 0d | AEMO |  |

| ID | WBS | Task | Type | Duration | Start | Finish | Predecessors | Total slack | Free slack | Responsibility |
| --- | --- | --- | --- | --- | --- | --- | --- | --- | --- | --- |
| 50 | 1.2.6.2 | **Draft Determination** |  | 61d | 2016-08-10 | 2016-11-02 |  | 274d |  |  |
| 51 | 1.2.6.2.1 | Develop Draft Determination |  | 28d | 2016-08-10 | 2016-09-16 | 49 | 253d | 0d | AEMO |
| 52 | 1.2.6.2.2 | **Obtain IEC Approval for B2B procedures** |  | 11d | 2016-09-19 | 2016-10-03 |  | 274d |  |  |
| 53 | 1.2.6.2.2.1 | Issue Draft Determination to IEC |  | 1d | 2016-09-19 | 2016-09-19 | 51 | 253d | 0d | AEMO |
| 54 | 1.2.6.2.2.2 | Obtain IEC approval for consultation |  | 10d | 2016-09-20 | 2016-10-03 | 53 | 253d | 0d | IEC |
| 55 | 1.2.6.2.3 | Commence second stage of consultation |  | 1d | 2016-10-11 | 2016-10-11 | 54FS+5d | 253d | 0d | AEMO |
| 56 | 1.2.6.2.4 | P - Draft Determination Work Pkg 1a & 1b | milestone | 0d | 2016-10-11 | 2016-10-11 | 55 | 600d |  |  |
| 57 | 1.2.6.2.5 | Draft Determination submissions |  | 15d | 2016-10-12 | 2016-11-01 | 55 | 274d | 0d | Industry |
| 58 | 1.2.6.2.6 | Second stage of consultation closed |  | 1d | 2016-11-02 | 2016-11-02 | 57 | 274d | 0d | AEMO |
| 59 | 1.2.6.3 | **Final Determination** |  | 30d | 2016-11-03 | 2016-12-14 | 57 | 274d |  |  |
| 60 | 1.2.6.3.1 | Develop Final Determination |  | 16d | 2016-11-03 | 2016-11-24 | 58 | 274d | 0d | AEMO |
| 61 | 1.2.6.3.2 | **Obtain IEC Approval for B2B procedures** |  | 8d | 2016-11-25 | 2016-12-06 |  | 274d |  |  |
| 62 | 1.2.6.3.2.1 | Issue Final Determination to IEC |  | 1d | 2016-11-25 | 2016-11-25 | 60 | 274d | 0d | AEMO |
| 63 | 1.2.6.3.2.2 | Obtain IEC approval for consultation |  | 7d | 2016-11-28 | 2016-12-06 | 62 | 274d | 0d | IEC |
| 64 | 1.2.6.3.3 | Publish Final Determination |  | 1d | 2016-12-14 | 2016-12-14 | 63FS+5d | 274d | 0d | AEMO |
| 65 | 1.2.6.3.4 | P - Final Determination - Work Pkg 1a & 1b | milestone | 0d | 2016-12-14 | 2016-12-14 | 64 | 554d |  |  |
| 66 | 1.2.7 | **Work Pkg 2** |  | 97d | 2016-10-06 | 2017-02-23 |  | 254d |  |  |
| 67 | 1.2.7.1 | Produce workshop #10 material - Work Pkg 2 |  | 10d | 2016-10-06 | 2016-10-19 | 6FS+216d | 253d | 0d | AEMO |
| 68 | 1.2.7.2 | Send WG workshop #10 material - Work Pkg 2 |  | 1d | 2016-10-20 | 2016-10-20 | 67 | 253d | 0d | AEMO |
| 69 | 1.2.7.3 | WG workshop #10 - Work Pkg 2 |  | 2d | 2016-11-04 | 2016-11-07 | 68FS+10d | 253d | 0d | Industry |
| 70 | 1.2.7.4 | Produce workshop #11 material - Work Pkg 2 |  | 10d | 2016-11-08 | 2016-11-21 | 69 | 253d | 0d | AEMO |
| 71 | 1.2.7.5 | Send WG workshop #11 material - Work Pkg 2 |  | 1d | 2016-11-22 | 2016-11-22 | 70 | 253d | 0d | AEMO |
| 72 | 1.2.7.6 | WG workshop #11 - Work Pkg 2 |  | 2d | 2016-12-07 | 2016-12-08 | 71FS+10d | 253d | 0d | Industry |
| 73 | 1.2.7.7 | Develop draft procedure #12 - Work Pkg 2 |  | 10d | 2016-12-09 | 2016-12-22 | 72 | 253d | 0d | AEMO |
| 74 | 1.2.7.8 | Send WG workshop #12 material - Work Pkg 2 |  | 1d | 2016-12-23 | 2016-12-23 | 73 | 253d | 0d | AEMO |
| 75 | 1.2.7.9 | WG workshop #12 - Work Pkg 2 |  | 2d | 2017-01-12 | 2017-01-13 | 74FS+10d | 253d | 0d | Industry |
| 76 | 1.2.7.10 | Develop draft procedure #13 - Work Pkg 2 |  | 15d | 2017-01-16 | 2017-02-06 | 75 | 253d | 0d | AEMO |
| 77 | 1.2.7.11 | Send WG workshop #13 material - Work Pkg 2 |  | 1d | 2017-02-07 | 2017-02-07 | 76 | 253d | 0d | AEMO |
| 78 | 1.2.7.12 | WG workshop #13 - Work Pkg 2 |  | 2d | 2017-02-22 | 2017-02-23 | 77FS+10d | 253d | 0d | Industry |

Notes:
- 51: Text Note: 28+11+5 = 45 days, extended period to review submissions and develop drafts
- 55: Text Note: Obtain IEC approval 5 days before consultation
- 57: Text Note: Extended consultation period
- 64: Text Note: Obtain IEC approval 5 days before consultation
- 67: Text Note: Work Pkg 2 starts when second consultation of first pkg begins
- 76: Text Note: Christmas period

| ID | WBS | Task | Type | Duration | Start | Finish | Predecessors | Total slack | Free slack | Responsibility | Text Note |
| --- | --- | --- | --- | --- | --- | --- | --- | --- | --- | --- | --- |
| 79 | 1.2.8 | **Consult'n - Pkg 2** |  | 100d | 2017-02-24 | 2017-07-25 |  | 254d |  |  |  |
| 80 | 1.2.8.1 | **Initial consultation** |  | 37d | 2017-02-24 | 2017-04-19 |  | 254d |  |  |  |
| 81 | 1.2.8.1.1 | Prepare consultation material |  | 10d | 2017-02-24 | 2017-03-09 | 78 | 253d | 0d | AEMO |  |
| 82 | 1.2.8.1.2 | Commence first stage of consultation |  | 1d | 2017-03-10 | 2017-03-10 | 81 | 253d | 0d | AEMO |  |
| 83 | 1.2.8.1.3 | P - Notice of consultation Work Pkg 2 | milestone | 0d | 2017-03-10 | 2017-03-10 | 82 | 496d |  |  |  |
| 84 | 1.2.8.1.4 | WG workshop #14 |  | 1d | 2017-04-03 | 2017-04-03 | 82FS+15d | 480d |  | Industry | Workshop 15 days after commencement of consultation |
| 85 | 1.2.8.1.5 | Submissions - Work Pkg 2 |  | 25d | 2017-03-13 | 2017-04-18 | 82 | 253d | 0d | Industry |  |
| 86 | 1.2.8.1.6 | First stage of consultation closed |  | 1d | 2017-04-19 | 2017-04-19 | 85 | 253d | 0d | AEMO |  |
| 87 | 1.2.8.2 | **Draft Determination** |  | 32d | 2017-04-20 | 2017-06-05 |  | 254d |  |  |  |
| 88 | 1.2.8.2.1 | Develop Draft Determination |  | 20d | 2017-04-20 | 2017-05-18 | 86 | 253d | 0d | AEMO |  |
| 89 | 1.2.8.2.2 | Commence second stage of consultation |  | 1d | 2017-05-19 | 2017-05-19 | 88 | 253d | 0d | AEMO |  |
| 90 | 1.2.8.2.3 | P - Draft Determination Work Pkg 2 | milestone | 0d | 2017-05-19 | 2017-05-19 | 89 | 449d |  |  |  |
| 91 | 1.2.8.2.4 | Draft Determination submissions |  | 10d | 2017-05-22 | 2017-06-02 | 89 | 253d | 0d | Industry |  |
| 92 | 1.2.8.2.5 | Second stage of consultation closed |  | 1d | 2017-06-05 | 2017-06-05 | 91 | 253d | 0d | AEMO |  |
| 93 | 1.2.8.3 | **Final Determination** |  | 31d | 2017-06-06 | 2017-07-25 | 91 | 254d |  |  |  |
| 94 | 1.2.8.3.1 | Develop Final Determination |  | 30d | 2017-06-06 | 2017-07-24 | 92 | 253d | 0d | AEMO |  |
| 95 | 1.2.8.3.2 | Publish Final Determination |  | 1d | 2017-07-25 | 2017-07-25 | 94 | 253d | 0d | AEMO |  |
| 96 | 1.2.8.3.3 | P - Final Determination - Work Pkg 2 | milestone | 0d | 2017-07-25 | 2017-07-25 | 95 | 407d |  |  |  |
| 97 | 1.2.9 | **Work Pkg 3** |  | 92d | 2017-05-11 | 2017-09-22 |  | 253d |  |  |  |
| 98 | 1.2.9.1 | Produce workshop #14 material - Work Pkg 3 |  | 10d | 2017-05-11 | 2017-05-24 | 6FS+364d | 253d | 0d | AEMO |  |
| 99 | 1.2.9.2 | Send WG workshop #14 material - Work Pkg 3 |  | 1d | 2017-05-25 | 2017-05-25 | 98 | 253d | 0d | AEMO |  |
| 100 | 1.2.9.3 | WG workshop #14 - Work Pkg 3 |  | 2d | 2017-06-09 | 2017-06-19 | 99FS+10d | 253d | 0d | Industry |  |
| 101 | 1.2.9.4 | Produce workshop #15 material - Work Pkg 3 |  | 10d | 2017-06-20 | 2017-07-03 | 100 | 253d | 0d | AEMO |  |
| 102 | 1.2.9.5 | Send WG workshop #15 material - Work Pkg 3 |  | 1d | 2017-07-04 | 2017-07-04 | 101 | 253d | 0d | AEMO |  |
| 103 | 1.2.9.6 | WG workshop #15 - Work Pkg 3 |  | 2d | 2017-07-19 | 2017-07-20 | 102FS+10d | 253d | 0d | Industry |  |
| 104 | 1.2.9.7 | Develop draft procedure # 16 - Work Pkg 3 |  | 10d | 2017-07-21 | 2017-08-03 | 103 | 253d | 0d | AEMO |  |
| 105 | 1.2.9.8 | Send WG workshop #16 material - Work Pkg 3 |  | 1d | 2017-08-04 | 2017-08-04 | 104 | 253d | 0d | AEMO |  |
| 106 | 1.2.9.9 | WG workshop #16 - Work Pkg 3 |  | 2d | 2017-08-21 | 2017-08-22 | 105FS+10d | 253d | 0d | Industry |  |
| 107 | 1.2.9.10 | Develop draft procedure # 16 - Work Pkg 3 |  | 10d | 2017-08-23 | 2017-09-05 | 106 | 253d | 0d | AEMO |  |
| 108 | 1.2.9.11 | Send WG workshop #16 material - Work Pkg 3 |  | 1d | 2017-09-06 | 2017-09-06 | 107 | 253d | 0d | AEMO |  |
| 109 | 1.2.9.12 | WG workshop #16 - Work Pkg 3 |  | 2d | 2017-09-21 | 2017-09-22 | 108FS+10d | 253d | 0d | Industry |  |

| ID | WBS | Task | Type | Duration | Start | Finish | Predecessors | Total slack | Free slack | Responsibility |
| --- | --- | --- | --- | --- | --- | --- | --- | --- | --- | --- |
| 110 | 1.2.10 | **Consult'n Pkg 3** |  | 110d | 2017-09-25 | 2018-02-27 |  | 254d |  |  |
| 111 | 1.2.10.1 | **Initial consultation** |  | 37d | 2017-09-25 | 2017-11-14 |  | 254d |  |  |
| 112 | 1.2.10.1.1 | Prepare consultation material |  | 10d | 2017-09-25 | 2017-10-06 | 109 | 253d | 0d | AEMO |
| 113 | 1.2.10.1.2 | Commence first stage of consultation |  | 1d | 2017-10-09 | 2017-10-09 | 112 | 253d | 0d | AEMO |
| 114 | 1.2.10.1.3 | P - Notice of consultation Work Pkg 3 | milestone | 0d | 2017-10-09 | 2017-10-09 | 113 | 353d |  |  |
| 115 | 1.2.10.1.4 | WG workshop #17 |  | 1d | 2017-10-31 | 2017-10-31 | 113FS+15d | 337d |  | Industry |
| 116 | 1.2.10.1.5 | Submissions - Work Pkg 3 |  | 25d | 2017-10-10 | 2017-11-13 | 113 | 253d | 0d | Industry |
| 117 | 1.2.10.1.6 | First stage of consultation closed |  | 1d | 2017-11-14 | 2017-11-14 | 116 | 253d | 0d | AEMO |
| 118 | 1.2.10.2 | **Draft Determination** |  | 42d | 2017-11-15 | 2018-01-15 |  | 254d |  |  |
| 119 | 1.2.10.2.1 | Develop Draft Determination |  | 20d | 2017-11-15 | 2017-12-12 | 117 | 253d | 0d | AEMO |
| 120 | 1.2.10.2.2 | Commence second stage of consultation |  | 1d | 2017-12-13 | 2017-12-13 | 119 | 253d | 0d | AEMO |
| 121 | 1.2.10.2.3 | P - Draft Determination Work Pkg 3 | milestone | 0d | 2017-12-13 | 2017-12-13 | 120 | 306d |  |  |
| 122 | 1.2.10.2.4 | Draft Determination submissions |  | 20d | 2017-12-14 | 2018-01-12 | 120 | 253d | 0d | Industry |
| 123 | 1.2.10.2.5 | Second stage of consultation closed |  | 1d | 2018-01-15 | 2018-01-15 | 122 | 253d | 0d | AEMO |
| 124 | 1.2.10.3 | **Final Determination** |  | 31d | 2018-01-16 | 2018-02-27 | 122 | 254d |  |  |
| 125 | 1.2.10.3.1 | Develop Final Determination |  | 30d | 2018-01-16 | 2018-02-26 | 123 | 253d | 0d | AEMO |
| 126 | 1.2.10.3.2 | Publish Final Determination |  | 1d | 2018-02-27 | 2018-02-27 | 125 | 253d | 0d | AEMO |
| 127 | 1.2.10.3.3 | P - Final Determination - Work Pkg 3 | milestone | 0d | 2018-02-27 | 2018-02-27 | 126 | 254d |  |  |
| 128 | 1.3 | **Distribution ring fencing guideline (MC)** |  | 253d | 2015-11-27 | 2016-11-25 |  | 588d |  |  |
| 129 | 1.3.1 | Develop Distribution fencing guideline |  | 253d | 2015-11-27 | 2016-11-25 | 6 | 567d |  | AER |
| 130 | 1.4 | **System change (MC)** |  | 346d | 2016-10-11 | 2018-02-27 |  | 275d |  |  |
| 131 | 1.4.1 | **System Development** |  | 346d | 2016-10-11 | 2018-02-27 |  | 275d |  |  |
| 132 | 1.4.1.1 | Write aseXML Change Request submission |  | 46d | 2016-12-15 | 2017-02-22 | 64 | 487d | 0d | AEMO |
| 133 | 1.4.1.2 | Submit aseXML Change Request to ASWG |  | 1d | 2017-02-23 | 2017-02-23 | 132 | 487d | 0d | AEMO |
| 134 | 1.4.1.3 | ASWG review of draft schema |  | 18d | 2017-02-24 | 2017-03-21 | 133 | 487d | 0d | ASWG |
| 135 | 1.4.1.4 | Participant system development |  | 300d | 2016-12-15 | 2018-02-27 | 64 | 274d | 0d | Industry |
| 136 | 1.4.1.5 | Draft schema released |  | 1d | 2017-03-22 | 2017-03-22 | 134 | 487d | 0d | ASWG |
| 137 | 1.4.1.6 | ASWG prepare final schema |  | 19d | 2017-03-23 | 2017-04-20 | 136 | 487d | 0d | ASWG |
| 138 | 1.4.1.7 | Final aseXML schema released |  | 1d | 2017-04-21 | 2017-04-21 | 137 | 487d | 0d | ASWG |
| 139 | 1.4.1.8 | AEMO system development |  | 120d | 2016-10-12 | 2017-04-03 | 55 | 288d | 0d | AEMO |
| 140 | 1.4.1.9 | S- System change stage starts | milestone | 0d | 2016-10-11 | 2016-10-11 | 55 | 600d |  |  |
| 141 | 1.4.1.10 | AEMO change notice published |  | 1d | 2017-04-24 | 2017-04-24 | 138 | 487d | 0d | AEMO |
| 142 | 1.4.1.11 | Update technical document & publish |  | 1d | 2017-04-26 | 2017-04-26 | 141 | 487d |  | AEMO |

Notes:
- 115: Text Note: workshop 15 days after commencement of consultation
- 122: Text Note: Allow two weeks for Christmas period
- 133: Text Note: Submit by specific date prior to meeting
- 135: Text Note: starts at Final Determination of work pkg 1, period includes pre-production

| ID | WBS | Task | Type | Duration | Start | Finish | Predecessors | Total slack | Free slack | Constraint | Responsibility | Text Note |
| --- | --- | --- | --- | --- | --- | --- | --- | --- | --- | --- | --- | --- |
| 143 | 1.4.2 | **System Implementation** |  | 201d | 2017-04-20 | 2018-02-07 |  | 289d |  |  |  |  |
| 144 | 1.4.2.1 | Pre-production |  | 41d | 2017-12-06 | 2018-02-02 | 139FS+168d | 288d | 0d |  | AEMO | Dev exp to be comp early |
| 145 | 1.4.2.2 | S - Pre-production period starts | milestone | 0d | 2017-04-20 | 2017-04-20 | 139FS+11d | 490d |  |  |  |  |
| 146 | 1.4.2.3 | Production |  | 1d | 2018-02-07 | 2018-02-07 | 144FS+2d | 288d | 0d |  | AEMO | Must be on Wed |
| 147 | 1.4.2.4 | S - System change phase ends | milestone | 0d | 2018-02-07 | 2018-02-07 | 146 | 289d |  |  |  |  |
| 148 | 1.5 | **Market Readiness (MC)** |  | 153d | 2017-07-25 | 2018-02-27 |  | 254d |  |  |  |  |
| 149 | 1.5.1 | M - Registration & Accreditation activities start | milestone | 0d | 2017-07-25 | 2017-07-25 | 95 | 407d |  |  |  |  |
| 150 | 1.5.2 | Registration & transitional (AMI meters) activities |  | 153d | 2017-07-26 | 2018-02-27 | 95 | 253d | 0d |  | AEMO |  |
| 151 | 1.5.3 | M - Readiness activities completed | milestone | 0d | 2018-02-27 | 2018-02-27 | 150 | 254d |  |  |  |  |
| 152 | 1.5.4 | Accreditation activities |  | 153d | 2017-07-26 | 2018-02-27 | 95 | 254d |  |  | AEMO |  |
| 153 | 1.6 | GO LIVE (MC) |  | 1d | 2018-02-28 | 2018-02-28 | 146, 126, 150, 144, 135 | 274d |  |  |  |  |
| 154 | 2 | **Embedded Networks (EN)** |  | 702d | 2015-05-21 | 2018-02-28 |  | 253d |  |  |  |  |
| 155 | 2.1 | **Rule Change (EN)** |  | 130d | 2015-05-21 | 2015-11-19 |  | 253d |  |  |  |  |
| 156 | 2.1.1 | R - Notice of consultation | milestone | 0d | 2015-05-21 | 2015-05-21 |  | 253d | 0d | start no earlier than 2015-05-21 | AEMC |  |
| 157 | 2.1.2 | Consultation submissions |  | 30d | 2015-05-21 | 2015-07-02 | 156 | 253d | 0d |  | Industry |  |
| 158 | 2.1.3 | Draft Determination |  | 50d | 2015-07-03 | 2015-09-10 | 157 | 253d | 0d |  | AEMC |  |
| 159 | 2.1.4 | R - Draft Determination | milestone | 0d | 2015-09-10 | 2015-09-10 | 158 | 875d |  |  |  |  |
| 160 | 2.1.5 | Consultation submissions |  | 30d | 2015-09-11 | 2015-10-22 | 158 | 253d | 0d |  | Industry |  |
| 161 | 2.1.6 | Final Determination |  | 20d | 2015-10-23 | 2015-11-19 | 160 | 253d | 0d |  | AEMC |  |
| 162 | 2.1.7 | EN Final Determination | milestone | 0d | 2015-11-19 | 2015-11-19 | 161 | 825d |  |  |  |  |
| 163 | 2.2 | **Procedure Change (EN)** |  | 393d | 2015-11-20 | 2017-06-20 |  | 259d |  |  |  |  |
| 164 | 2.2.1 | **Work Pkg 1 (EN)** |  | 95d | 2015-11-20 | 2016-04-08 |  | 259d |  |  |  |  |
| 165 | 2.2.1.1 | Procedure development Pkg 1 |  | 60d | 2015-11-20 | 2016-02-17 | 161 | 765d |  |  | AEMO |  |
| 166 | 2.2.1.2 | Produce workshop #1 material - Work Pkg 1 |  | 5d | 2015-11-20 | 2015-11-26 | 161 | 254d | 0d |  | AEMO |  |
| 167 | 2.2.1.3 | Send WG workshop #1 material - Work Pkg 1 |  | 1d | 2015-11-27 | 2015-11-27 | 166 | 254d | 0d | start no earlier than 2015-07-08 | AEMO |  |
| 168 | 2.2.1.4 | WG workshop #1 - Work Pkg 1 |  | 2d | 2015-12-14 | 2015-12-15 | 167FS+10d | 254d | 0d |  | Industry |  |
| 169 | 2.2.1.5 | Develop draft procedure #2 - Work Pkg 1 |  | 20d | 2015-12-16 | 2016-01-15 | 168 | 254d | 0d |  | AEMO | Increased duration to allow for Christmas period |
| 170 | 2.2.1.6 | Send WG workshop #2 material - Work Pkg 1 |  | 1d | 2016-01-18 | 2016-01-18 | 169 | 254d | 0d |  | AEMO |  |
| 171 | 2.2.1.7 | WG workshop #2 - Work Pkg 1 |  | 2d | 2016-02-03 | 2016-02-04 | 170FS+10d | 254d | 0d |  | Industry |  |
| 172 | 2.2.1.8 | Update draft procedure #3 - Work Pkg 1 |  | 10d | 2016-02-05 | 2016-02-18 | 171 | 254d | 0d |  | AEMO |  |
| 173 | 2.2.1.9 | Send WG workshop #3 material - Work Pkg 1 |  | 1d | 2016-02-19 | 2016-02-19 | 172 | 763d |  |  |  |  |
| 174 | 2.2.1.10 | WG workshop #3 - Work Pkg 1 |  | 2d | 2016-03-04 | 2016-03-07 | 172FS+10d | 254d | 0d |  | Industry |  |
| 175 | 2.2.1.11 | Update draft procedure #4 - Work Pkg 1 |  | 10d | 2016-03-08 | 2016-03-21 | 174 | 254d | 0d |  | AEMO |  |
| 176 | 2.2.1.12 | Send WG workshop #4 material - Work Pkg 1 |  | 1d | 2016-03-22 | 2016-03-22 | 175 | 741d |  |  | AEMO |  |
| 177 | 2.2.1.13 | WG workshop #4 - Work Pkg 1 |  | 2d | 2016-04-07 | 2016-04-08 | 175FS+10d | 254d | 0d |  | Industry |  |

| ID | WBS | Task | Type | Duration | Start | Finish | Predecessors | Total slack | Free slack | Responsibility | Text Note |
| --- | --- | --- | --- | --- | --- | --- | --- | --- | --- | --- | --- |
| 178 | 2.2.2 | **Consult'n (EN) - Work Pkg 1** |  | 175d | 2016-04-11 | 2016-12-13 |  | 259d |  |  |  |
| 179 | 2.2.2.1 | **Initial consultation** |  | 83d | 2016-04-11 | 2016-08-05 |  | 259d |  |  |  |
| 180 | 2.2.2.1.1 | Prepare consultation material |  | 30d | 2016-04-11 | 2016-05-23 | 177 | 254d | 0d | AEMO | Extended duration to align consultation period with MC |
| 181 | 2.2.2.1.2 | **Obtain IEC Approval for B2B procedures** |  | 11d | 2016-05-24 | 2016-06-07 |  | 259d |  |  |  |
| 182 | 2.2.2.1.2.1 | Issue consultation papers to IEC |  | 1d | 2016-05-24 | 2016-05-24 | 180 | 254d | 0d | AEMO |  |
| 183 | 2.2.2.1.2.2 | Obtain IEC approval for consultation |  | 10d | 2016-05-25 | 2016-06-07 | 182 | 254d | 0d | IEC |  |
| 184 | 2.2.2.1.3 | Commence first stage of consultation |  | 1d | 2016-06-16 | 2016-06-16 | 183FS+5d | 254d | 0d | AEMO | Obtain IEC approval 5 days before consultation |
| 185 | 2.2.2.1.4 | P - Notice of consultation Work Pkg 1 | milestone | 0d | 2016-06-16 | 2016-06-16 | 184 | 683d |  |  |  |
| 186 | 2.2.2.1.5 | WG workshop #5 |  | 1d | 2016-07-08 | 2016-07-08 | 184FS+15d | 667d |  | AEMO | workshop 15 days after commencement of consultation |
| 187 | 2.2.2.1.6 | Submissions - Work Pkg 1 |  | 35d | 2016-06-17 | 2016-08-04 | 184 | 254d | 0d | Industry |  |
| 188 | 2.2.2.1.7 | First stage of consultation closed |  | 1d | 2016-08-05 | 2016-08-05 | 187 | 254d | 0d | AEMO |  |
| 189 | 2.2.2.2 | **Draft Determination** |  | 62d | 2016-08-08 | 2016-11-01 |  | 259d |  |  | 28+11+5 = 44 days |
| 190 | 2.2.2.2.1 | Develop Draft Determination |  | 29d | 2016-08-08 | 2016-09-15 | 188 | 254d | 0d | AEMO |  |
| 191 | 2.2.2.2.2 | **Obtain IEC Approval for B2B procedures** |  | 11d | 2016-09-16 | 2016-09-30 |  | 259d |  |  |  |
| 192 | 2.2.2.2.2.1 | Issue Draft Determination to IEC |  | 1d | 2016-09-16 | 2016-09-16 | 190 | 254d | 0d | AEMO |  |
| 193 | 2.2.2.2.2.2 | Obtain IEC approval for consultation |  | 10d | 2016-09-19 | 2016-09-30 | 192 | 254d | 0d | IEC |  |
| 194 | 2.2.2.2.3 | Commence second stage of consultation |  | 1d | 2016-10-10 | 2016-10-10 | 193FS+5d | 254d | 0d | AEMO | Obtain IEC approval 5 days before consultation |
| 195 | 2.2.2.2.4 | P - Draft Determination Work Pkg 1 | milestone | 0d | 2016-10-10 | 2016-10-10 | 194 | 601d |  |  |  |
| 196 | 2.2.2.2.5 | Draft Determination submissions |  | 15d | 2016-10-11 | 2016-10-31 | 194 | 254d | 0d | Industry |  |
| 197 | 2.2.2.2.6 | Second stage of consultation closed |  | 1d | 2016-11-01 | 2016-11-01 | 196 | 254d | 0d |  |  |
| 198 | 2.2.2.3 | **Final Determination** |  | 30d | 2016-11-02 | 2016-12-13 | 196 | 259d |  |  |  |
| 199 | 2.2.2.3.1 | Develop Final Determination |  | 16d | 2016-11-02 | 2016-11-23 | 197 | 254d | 0d | AEMO |  |
| 200 | 2.2.2.3.2 | **Obtain IEC Approval for B2B procedures** |  | 8d | 2016-11-24 | 2016-12-05 |  | 259d |  |  |  |
| 201 | 2.2.2.3.2.1 | Issue Final Determination to IEC |  | 1d | 2016-11-24 | 2016-11-24 | 199 | 254d | 0d | AEMO |  |
| 202 | 2.2.2.3.2.2 | Obtain IEC approval for consultation |  | 7d | 2016-11-25 | 2016-12-05 | 201 | 254d | 0d | IEC |  |
| 203 | 2.2.2.3.3 | Publish Final Determination |  | 1d | 2016-12-13 | 2016-12-13 | 202FS+5d | 254d | 0d | AEMO |  |
| 204 | 2.2.2.3.4 | P - Final Determination - Work Pkg 1 | milestone | 0d | 2016-12-13 | 2016-12-13 | 203 | 555d |  |  |  |

| ID | WBS | Task | Type | Duration | Start | Finish | Predecessors | Total slack | Free slack | Responsibility | Text Note |
| --- | --- | --- | --- | --- | --- | --- | --- | --- | --- | --- | --- |
| 205 | 2.2.3 | **Work Pkg 2** |  | 88d | 2016-09-14 | 2017-01-18 |  | 253d |  |  |  |
| 206 | 2.2.3.1 | Produce workshop #6 material - Work Pkg 2 |  | 10d | 2016-09-14 | 2016-09-27 | 161FS+205d | 253d | 0d | AEMO |  |
| 207 | 2.2.3.2 | Send WG workshop #6 material - Work Pkg 2 |  | 1d | 2016-09-28 | 2016-09-28 | 206 | 253d | 0d | AEMO |  |
| 208 | 2.2.3.3 | WG workshop #6 - Work Pkg 2 |  | 1d | 2016-10-13 | 2016-10-13 | 207FS+10d | 253d | 0d | Industry |  |
| 209 | 2.2.3.4 | Produce workshop #7 material - Work Pkg 2 |  | 10d | 2016-10-14 | 2016-10-27 | 208 | 253d | 0d | AEMO |  |
| 210 | 2.2.3.5 | Send WG workshop #7 material - Work Pkg 2 |  | 1d | 2016-10-28 | 2016-10-28 | 209 | 253d | 0d | AEMO |  |
| 211 | 2.2.3.6 | WG workshop #7 - Work Pkg 2 |  | 1d | 2016-11-14 | 2016-11-14 | 210FS+10d | 253d | 0d | Industry |  |
| 212 | 2.2.3.7 | Update draft procedure #8 - Work Pkg 2 |  | 10d | 2016-11-15 | 2016-11-28 | 211 | 253d | 0d | AEMO |  |
| 213 | 2.2.3.8 | Send WG workshop #8 material - Work Pkg 2 |  | 1d | 2016-11-29 | 2016-11-29 | 212 | 253d | 0d | AEMO |  |
| 214 | 2.2.3.9 | WG workshop #8 - Work Pkg 2 |  | 1d | 2016-12-14 | 2016-12-14 | 213FS+10d | 253d | 0d | Industry |  |
| 215 | 2.2.3.10 | Update draft procedure #9 - Work Pkg 2 |  | 10d | 2016-12-15 | 2016-12-30 | 214 | 253d | 0d | AEMO |  |
| 216 | 2.2.3.11 | Send WG workshop #9 material - Work Pkg 2 |  | 1d | 2017-01-03 | 2017-01-03 | 215 | 253d | 0d | AEMO |  |
| 217 | 2.2.3.12 | WG workshop #9 - Work Pkg 2 |  | 1d | 2017-01-18 | 2017-01-18 | 216FS+10d | 253d | 0d | Industry |  |
| 218 | 2.2.4 | **Consult'n (EN) - Work Pkg 2** |  | 100d | 2017-01-19 | 2017-06-20 |  | 253d |  |  |  |
| 219 | 2.2.4.1 | **Initial consultation** |  | 37d | 2017-01-19 | 2017-03-13 |  | 253d |  |  |  |
| 220 | 2.2.4.1.1 | Prepare consultation material |  | 10d | 2017-01-19 | 2017-02-02 | 214, 217 | 253d | 0d | AEMO |  |
| 221 | 2.2.4.1.2 | Commence first stage of consultation |  | 1d | 2017-02-03 | 2017-02-03 | 220 | 253d | 0d | AEMO |  |
| 222 | 2.2.4.1.3 | P - Notice of consultation Work Pkg 2 | milestone | 0d | 2017-02-03 | 2017-02-03 | 221 | 521d |  |  |  |
| 223 | 2.2.4.1.4 | WG workshop #13 |  | 1d | 2017-02-20 | 2017-02-20 | 221FS+10d | 510d |  | Industry | workshop 10 days after commencement of consultation |
| 224 | 2.2.4.1.5 | Submissions - Work Pkg 2 |  | 25d | 2017-02-06 | 2017-03-10 | 221 | 253d | 0d | Industry |  |
| 225 | 2.2.4.1.6 | First stage of consultation closed |  | 1d | 2017-03-13 | 2017-03-13 | 224 | 253d | 0d | AEMO |  |
| 226 | 2.2.4.2 | **Draft Determination** |  | 32d | 2017-03-14 | 2017-05-01 |  | 253d |  |  |  |
| 227 | 2.2.4.2.1 | Develop Draft Determination |  | 20d | 2017-03-14 | 2017-04-10 | 225 | 253d | 0d | AEMO |  |
| 228 | 2.2.4.2.2 | Commence second stage of consultation |  | 1d | 2017-04-11 | 2017-04-11 | 227 | 253d | 0d | AEMO |  |
| 229 | 2.2.4.2.3 | P - Draft Determination Work Pkg 2 | milestone | 0d | 2017-04-11 | 2017-04-11 | 228 | 474d |  |  |  |
| 230 | 2.2.4.2.4 | Draft Determination submissions |  | 10d | 2017-04-12 | 2017-04-28 | 228 | 253d | 0d | Industry |  |
| 231 | 2.2.4.2.5 | Second stage of consultation closed |  | 1d | 2017-05-01 | 2017-05-01 | 230 | 253d | 0d | AEMO |  |

| ID | WBS | Task | Type | Duration | Start | Finish | Predecessors | Total slack | Free slack | Responsibility | Text Note |
| --- | --- | --- | --- | --- | --- | --- | --- | --- | --- | --- | --- |
| 232 | 2.2.4.3 | **Final Determination** |  | 31d | 2017-05-02 | 2017-06-20 | 230 | 253d |  |  |  |
| 233 | 2.2.4.3.1 | Develop Final Determination |  | 30d | 2017-05-02 | 2017-06-19 | 231 | 253d | 0d | AEMO |  |
| 234 | 2.2.4.3.2 | Publish Final Determination |  | 1d | 2017-06-20 | 2017-06-20 | 233 | 253d | 0d | AEMO |  |
| 235 | 2.2.4.3.3 | P - Final Determination - Work Pkg 2 | milestone | 0d | 2017-06-20 | 2017-06-20 | 234 | 432d |  |  |  |
| 236 | 2.3 | **System Change (EN)** |  | 346d | 2016-10-10 | 2018-02-26 |  | 275d |  |  |  |
| 237 | 2.3.1 | **System Development** |  | 346d | 2016-10-10 | 2018-02-26 |  | 275d |  |  |  |
| 238 | 2.3.1.1 | Write aseXML Change Request submission |  | 46d | 2016-12-14 | 2017-02-21 | 203 | 309d | 0d | AEMO |  |
| 239 | 2.3.1.2 | Submit aseXML Change Request to ASWG |  | 1d | 2017-02-22 | 2017-02-22 | 238 | 309d | 0d | AEMO |  |
| 240 | 2.3.1.3 | ASWG review of draft schema |  | 18d | 2017-02-23 | 2017-03-20 | 239 | 309d | 0d | ASWG |  |
| 241 | 2.3.1.4 | Participant system development (EN) |  | 300d | 2016-12-14 | 2018-02-26 | 203 | 254d | 1d | Industry |  |
| 242 | 2.3.1.5 | Draft schema released |  | 1d | 2017-03-21 | 2017-03-21 | 240 | 309d | 0d | ASWG |  |
| 243 | 2.3.1.6 | ASWG prepare final schema |  | 19d | 2017-03-22 | 2017-04-19 | 242 | 309d | 0d | ASWG |  |
| 244 | 2.3.1.7 | Final aseXML schema released |  | 1d | 2017-04-20 | 2017-04-20 | 243 | 309d | 0d | ASWG |  |
| 245 | 2.3.1.8 | AEMO system development |  | 233d | 2016-12-14 | 2017-11-21 | 203 | 258d | 0d | AEMO | Reflect AEMO realistic duration |
| 246 | 2.3.1.9 | S- System change stage starts | milestone | 0d | 2016-10-10 | 2016-10-10 | 194 | 601d |  |  |  |
| 247 | 2.3.1.10 | AEMO change notice published |  | 1d | 2017-09-26 | 2017-09-26 | 244FS+106d | 309d | 0d | AEMO |  |
| 248 | 2.3.1.11 | Update technical document & publish |  | 1d | 2017-12-08 | 2017-12-08 | 247FS+52d | 309d |  | AEMO |  |
| 249 | 2.3.2 | **System Implementation** |  | 53d | 2017-12-06 | 2018-02-20 |  | 259d |  |  |  |
| 250 | 2.3.2.1 | Pre-production |  | 40d | 2017-12-06 | 2018-02-01 | 245FS+10d | 258d | 0d | AEMO |  |
| 251 | 2.3.2.2 | S - Pre-production period starts | milestone | 0d | 2017-12-07 | 2017-12-07 | 245FS+12d | 310d |  |  |  |
| 252 | 2.3.2.3 | Production |  | 1d | 2018-02-20 | 2018-02-20 | 250FS+12d | 258d | 0d | AEMO |  |
| 253 | 2.3.2.4 | S - System change phase ends | milestone | 0d | 2018-02-20 | 2018-02-20 | 252 | 259d |  |  |  |
| 254 | 2.4 | **Market Readiness (EN)** |  | 178d | 2017-06-20 | 2018-02-27 |  | 253d |  |  |  |
| 255 | 2.4.1 | Readiness Activities |  | 178d | 2017-06-21 | 2018-02-27 | 234 | 253d | 0d | AEMO |  |
| 256 | 2.4.2 | M - Market Registration & Accreditation starts | milestone | 0d | 2017-06-20 | 2017-06-20 | 234 | 431d |  |  |  |
| 257 | 2.4.3 | M - Market Readiness activities completed | milestone | 0d | 2018-02-27 | 2018-02-27 | 255 | 253d |  |  |  |
| 258 | 2.5 | GO LIVE (EN) |  | 1d | 2018-02-28 | 2018-02-28 | 255, 252, 234, 241 | 274d |  |  |  |

| ID | WBS | Task | Type | Duration | Start | Finish | Predecessors | Total slack | Free slack | Constraint | Responsibility |
| --- | --- | --- | --- | --- | --- | --- | --- | --- | --- | --- | --- |
| 259 | 3 | **Shared Market Protocols (SMP)** |  | 859d | 2015-11-03 | 2019-03-19 |  | 0d |  |  |  |
| 260 | 3.1 | **Rule Change (SMP)** |  | 122d | 2015-11-03 | 2016-04-29 |  | 0d |  |  |  |
| 261 | 3.1.1 | Notice of consultation |  | 20d | 2015-11-03 | 2015-11-30 |  | 0d |  | finish no earlier than 2015-11-30 | AEMC |
| 262 | 3.1.2 | R - Notice of consultation | milestone | 0d | 2015-11-30 | 2015-11-30 | 261 | 818d |  |  |  |
| 263 | 3.1.3 | Consultation submissions |  | 20d | 2015-12-01 | 2015-12-30 | 261 | 0d |  |  | Industry |
| 264 | 3.1.4 | Draft Determination |  | 41d | 2015-12-31 | 2016-02-29 | 263 | 0d |  |  | AEMC |
| 265 | 3.1.5 | R - Draft Determination | milestone | 0d | 2016-02-29 | 2016-02-29 | 264 | 757d |  |  |  |
| 266 | 3.1.6 | Consultation submissions (draft) |  | 30d | 2016-03-01 | 2016-04-13 | 264 | 0d |  |  | Industry |
| 267 | 3.1.7 | Final Determination |  | 11d | 2016-04-14 | 2016-04-29 | 266 | 0d |  |  | AEMC |
| 268 | 3.1.8 | R - Final Determination | milestone | 0d | 2016-04-29 | 2016-04-29 | 267 | 716d |  |  |  |
| 269 | 3.2 | **Procedure Change (SMP)** |  | 475d | 2016-05-02 | 2018-03-16 |  | 0d |  |  |  |
| 270 | 3.2.1 | **Procedure development (SMP) - Work Pkg 1** |  | 240d | 2016-05-02 | 2017-04-07 |  | 0d |  |  |  |
| 271 | 3.2.1.1 | Procedure development Pkg 1 |  | 240d | 2016-05-02 | 2017-04-07 | 267 | 0d |  |  | AEMO |
| 272 | 3.2.2 | **Procedure consultation (SMP) - Work Pkg 1** |  | 135d | 2017-04-10 | 2017-10-25 |  | 0d |  |  |  |
| 273 | 3.2.2.1 | Notice of consultation Pkg 1 |  | 10d | 2017-04-10 | 2017-04-26 | 271 | 0d |  |  | AEMO |
| 274 | 3.2.2.2 | Consultation submissions Pkg 1 |  | 35d | 2017-04-27 | 2017-06-21 | 273 | 0d |  |  | Industry |
| 275 | 3.2.2.3 | Draft determination Pkg 1 |  | 45d | 2017-06-22 | 2017-08-23 | 274 | 0d |  |  | AEMO |
| 276 | 3.2.2.4 | Consultation submission Pkg 1 (draft) |  | 15d | 2017-08-24 | 2017-09-13 | 275 | 1d | 0d |  | Industry |
| 277 | 3.2.2.5 | Final determination Pkg 1 |  | 30d | 2017-09-14 | 2017-10-25 | 276 | 1d | 0d |  | AEMO |
| 278 | 3.2.2.6 | P - Final Determination Work Pkg 1 | milestone | 0d | 2017-10-25 | 2017-10-25 | 277 | 341d |  |  |  |
| 279 | 3.2.3 | **Procedure development (SMP) - Work Pkg 2** |  | 40d | 2017-08-24 | 2017-10-18 |  | 0d |  |  | AEMO |
| 280 | 3.2.3.1 | Procedure development Pkg 2 |  | 40d | 2017-08-24 | 2017-10-18 | 275 | 0d |  |  | AEMO |
| 281 | 3.2.4 | **Procedure consultation (SMP) - Work Pkg 2** |  | 105d | 2017-10-19 | 2018-03-16 |  | 0d |  |  |  |
| 282 | 3.2.4.1 | Notice of consultation Pkg 2 |  | 20d | 2017-10-19 | 2017-11-15 | 280 | 0d |  |  | AEMO |
| 283 | 3.2.4.2 | Consultation submissions Pkg 2 |  | 25d | 2017-11-16 | 2017-12-20 | 282 | 0d |  |  | Industry |
| 284 | 3.2.4.3 | Draft determination Pkg 2 |  | 20d | 2017-12-21 | 2018-01-19 | 283 | 0d |  |  | AEMO |
| 285 | 3.2.4.4 | Consultation submissions Pkg 2 (draft) |  | 10d | 2018-01-22 | 2018-02-02 | 284 | 0d |  |  | Industry |
| 286 | 3.2.4.5 | Final determination Pkg 2 |  | 30d | 2018-02-05 | 2018-03-16 | 285 | 0d |  |  | AEMO |
| 287 | 3.2.4.6 | P - Final Determination Work Pkg 2 | milestone | 0d | 2018-03-16 | 2018-03-16 | 286 | 241d |  |  |  |

Notes:
- 269: AEMO development of SMP, MTR and DRM cannot occur at the same time due to constraints in SME resources. Timelines for SMP, MTR & DRM will need to be reviewed when dates are confirmed.

| ID | WBS | Task | Type | Duration | Start | Finish | Predecessors | Total slack | Free slack | Constraint | Responsibility |
| --- | --- | --- | --- | --- | --- | --- | --- | --- | --- | --- | --- |
| 288 | 3.3 | **System Change (SMP)** |  | 586d | 2016-11-28 | 2019-03-15 |  | 2d |  |  |  |
| 289 | 3.3.1 | Buildpack development |  | 90d | 2016-11-28 | 2017-04-06 | 266FS+160d | 477d |  |  | AEMO |
| 290 | 3.3.2 | Design, Build, Test |  | 300d | 2017-10-26 | 2018-12-21 | 277 | 1d | 0d |  | Industry |
| 291 | 3.3.3 | Design, Build, Test |  | 345d | 2017-08-24 | 2018-12-21 | 275 | 1d | 0d |  | AEMO |
| 292 | 3.3.4 | S - System change phase starts | milestone | 0d | 2017-08-23 | 2017-08-23 | 275 | 386d |  |  |  |
| 293 | 3.3.5 | Pre-production |  | 60d | 2018-12-24 | 2019-03-15 | 290, 291 | 1d |  |  |  |
| 294 | 3.3.6 | S - System change phase ends | milestone | 0d | 2018-12-21 | 2018-12-21 | 290 | 41d |  |  |  |
| 295 | 3.4 | **Market Readiness (SMP)** |  | 261d | 2018-03-16 | 2019-03-18 |  | 0d |  |  |  |
| 296 | 3.4.1 | Readiness Activities |  | 261d | 2018-03-19 | 2019-03-18 | 286 | 0d |  |  | AEMO |
| 297 | 3.4.2 | M - Market Readiness activities start | milestone | 0d | 2018-03-16 | 2018-03-16 | 286 | 241d |  |  |  |
| 298 | 3.4.3 | M - Market Readiness activities completed | milestone | 0d | 2019-03-18 | 2019-03-18 | 296 | 1d |  |  |  |
| 299 | 3.5 | GO LIVE (SMP) |  | 1d | 2019-03-19 | 2019-03-19 | 290, 286, 296, 293 | 0d |  |  |  |
| 300 | 4 | **Multiple Trading Relationships (MTR)** |  | 852d | 2015-06-29 | 2018-11-01 |  | 98d |  |  |  |
| 301 | 4.1 | **Rule Change (MTR)** |  | 322d | 2015-06-29 | 2016-09-30 |  | 105d |  |  |  |
| 302 | 4.1.1 | Notice of consultation |  | 25d | 2015-06-29 | 2015-07-31 |  | 84d | 0d | finish no earlier than 2015-07-31 | AEMC |
| 303 | 4.1.2 | R - Notice of consultation | milestone | 0d | 2015-07-31 | 2015-07-31 | 302 | 904d |  |  |  |
| 304 | 4.1.3 | Consultation submissions |  | 195d | 2015-08-03 | 2016-05-10 | 302 | 84d | 7d |  | Industry |
| 305 | 4.1.4 | Draft Determination |  | 50d | 2016-05-20 | 2016-07-29 | 304 | 98d | 0d | finish no earlier than 2016-07-29 | AEMC |
| 306 | 4.1.5 | R - Draft Determination | milestone | 0d | 2016-07-29 | 2016-07-29 | 305 | 652d |  |  |  |
| 307 | 4.1.6 | Consultation submissions (draft) |  | 30d | 2016-08-01 | 2016-09-09 | 305 | 77d | 0d |  | Industry |
| 308 | 4.1.7 | Final Determination |  | 15d | 2016-09-12 | 2016-09-30 | 307 | 77d | 0d |  | AEMC |
| 309 | 4.1.8 | R - Final Determination | milestone | 0d | 2016-09-30 | 2016-09-30 | 308 | 607d |  |  |  |
| 310 | 4.2 | **Procedure Change (MTR)** |  | 209d | 2016-10-03 | 2017-08-07 |  | 98d |  |  |  |
| 311 | 4.2.1 | Procedure development |  | 65d | 2016-10-03 | 2017-01-04 | 308 | 77d | 0d |  | AEMO |
| 312 | 4.2.2 | Notice of consultation |  | 20d | 2017-01-05 | 2017-02-02 | 311 | 77d | 0d |  | AEMO |
| 313 | 4.2.3 | Consultation submissions |  | 35d | 2017-02-03 | 2017-03-23 | 312 | 77d | 0d |  | Industry |
| 314 | 4.2.4 | Draft Determination |  | 45d | 2017-03-24 | 2017-05-30 | 313 | 77d | 0d |  | AEMO |
| 315 | 4.2.5 | Consultation submissions (draft) |  | 15d | 2017-05-31 | 2017-06-27 | 314 | 77d | 0d |  | Industry |
| 316 | 4.2.6 | Final Determination |  | 29d | 2017-06-28 | 2017-08-07 | 315 | 77d | 0d |  | AEMO |
| 317 | 4.2.7 | P - Final Determination | milestone | 0d | 2017-08-07 | 2017-08-07 | 316 | 398d |  |  |  |

| ID | WBS | Task | Type | Duration | Start | Finish | Predecessors | Total slack | Free slack | Constraint | Responsibility |
| --- | --- | --- | --- | --- | --- | --- | --- | --- | --- | --- | --- |
| 318 | 4.3 | **System Change (MTR)** |  | 364d | 2017-05-30 | 2018-10-31 |  | 99d |  |  |  |
| 319 | 4.3.1 | Design, Build, Test |  | 300d | 2017-08-08 | 2018-10-03 | 316 | 98d | 0d |  | Industry |
| 320 | 4.3.2 | Design, Build, Test |  | 340d | 2017-05-31 | 2018-09-27 | 314 | 81d | 4d |  | AEMO |
| 321 | 4.3.3 | S- System change phase starts | milestone | 0d | 2017-05-30 | 2017-05-30 | 314 | 442d |  |  |  |
| 322 | 4.3.4 | Pre-production |  | 20d | 2018-10-04 | 2018-10-31 | 319, 320 | 98d | 0d |  | AEMO |
| 323 | 4.3.5 | S - System change phase ends | milestone | 0d | 2018-10-31 | 2018-10-31 | 322 | 78d |  |  |  |
| 324 | 4.4 | **Market Readiness (MTR)** |  | 318d | 2017-08-07 | 2018-10-29 |  | 101d |  |  |  |
| 325 | 4.4.1 | Readiness Activities |  | 150d | 2018-04-03 | 2018-10-29 | 316FS+168d | 100d | 2d |  | AEMO |
| 326 | 4.4.2 | M - Market Readiness Activities start | milestone | 0d | 2017-08-07 | 2017-08-07 | 316 | 398d |  |  |  |
| 327 | 4.5 | GO LIVE (MTR) |  | 1d | 2018-11-01 | 2018-11-01 | 319, 322, 325 | 98d |  |  |  |
| 328 | 5 | **Demand Response Mechanism (DRM)** |  | 826d | 2015-11-03 | 2019-01-31 |  | 33d |  |  |  |
| 329 | 5.1 | **Rule Change (DRM)** |  | 310d | 2015-11-03 | 2017-01-24 |  | 33d |  |  |  |
| 330 | 5.1.1 | Notice of consultation |  | 20d | 2015-11-03 | 2015-11-30 |  | 12d | 0d | finish no earlier than 2015-11-30 | AEMC |
| 331 | 5.1.2 | R - Notice of consultation | milestone | 0d | 2015-11-30 | 2015-11-30 | 330 | 818d |  |  |  |
| 332 | 5.1.3 | Consultation submissions |  | 190d | 2015-12-01 | 2016-09-01 | 330 | 12d | 0d |  | Industry |
| 333 | 5.1.4 | Draft Determination |  | 50d | 2016-09-02 | 2016-11-10 | 332 | 12d | 0d |  | AEMC |
| 334 | 5.1.5 | R - Draft Determination | milestone | 0d | 2016-11-10 | 2016-11-10 | 333 | 578d |  |  |  |
| 335 | 5.1.6 | Consultation submissions (draft) |  | 20d | 2016-11-11 | 2016-12-08 | 333 | 528d | 0d |  | Industry |
| 336 | 5.1.7 | Final Determination |  | 30d | 2016-12-09 | 2017-01-24 | 335 | 528d | 0d |  | AEMC |
| 337 | 5.1.8 | R - Final Determination | milestone | 0d | 2017-01-24 | 2017-01-24 | 336 | 528d |  |  |  |
| 338 | 5.2 | **Procedure Change (DRM)** |  | 225d | 2016-11-11 | 2017-10-09 |  | 33d |  |  |  |
| 339 | 5.2.1 | Procedure development |  | 80d | 2016-11-11 | 2017-03-08 | 333 | 12d | 0d |  | AEMO |
| 340 | 5.2.2 | Notice of consultation |  | 20d | 2017-03-09 | 2017-04-05 | 339 | 12d | 0d |  | AEMO |
| 341 | 5.2.3 | Consultation submissions |  | 35d | 2017-04-06 | 2017-05-29 | 340 | 12d | 0d |  | Industry |
| 342 | 5.2.4 | Draft Determination |  | 45d | 2017-05-30 | 2017-08-07 | 341 | 12d | 0d |  | AEMO |
| 343 | 5.2.5 | Consultation submissions (draft) |  | 15d | 2017-08-08 | 2017-08-28 | 342 | 12d | 0d |  | Industry |
| 344 | 5.2.6 | Final Determination |  | 30d | 2017-08-29 | 2017-10-09 | 343 | 12d | 0d |  | AEMO |
| 345 | 5.2.7 | P - Final Determination | milestone | 0d | 2017-10-09 | 2017-10-09 | 344 | 353d |  |  |  |

| ID | WBS | Task | Type | Duration | Start | Finish | Predecessors | Total slack | Free slack | Constraint | Responsibility |
| --- | --- | --- | --- | --- | --- | --- | --- | --- | --- | --- | --- |
| 346 | 5.3 | **System Change (DRM)** |  | 385d | 2017-08-07 | 2019-01-30 |  | 33d |  |  |  |
| 347 | 5.3.1 | Design, Build, Test |  | 300d | 2017-10-10 | 2018-12-05 | 344 | 12d | 0d |  | Industry |
| 348 | 5.3.2 | Design, Build, Test |  | 345d | 2017-08-08 | 2018-12-05 | 342 | 12d | 0d |  | AEMO |
| 349 | 5.3.3 | S - System change phase starts | milestone | 0d | 2017-08-07 | 2017-08-07 | 342 | 398d |  |  |  |
| 350 | 5.3.4 | Pre-production |  | 40d | 2018-12-06 | 2019-01-30 | 347, 348 | 12d | 0d |  |  |
| 351 | 5.3.5 | S - System change phase ends | milestone | 0d | 2018-12-05 | 2018-12-05 | 347, 348 | 53d |  |  |  |
| 352 | 5.4 | **Market Readiness (DRM)** |  | 220d | 2018-03-28 | 2019-01-30 |  | 33d |  |  |  |
| 353 | 5.4.1 | Readiness Activities |  | 220d | 2018-03-29 | 2019-01-30 | 344FS+120d | 33d | 0d |  | AEMO |
| 354 | 5.4.2 | M - Market Readiness Activities start | milestone | 0d | 2018-03-28 | 2018-03-28 | 344FS+120d | 233d |  |  |  |
| 355 | 5.5 | GO LIVE (DRM) |  | 1d | 2019-01-31 | 2019-01-31 | 347, 353, 348, 350 | 33d |  |  |  |
| 356 | 6 | **Meter Replacement Processes (MRP)** |  | 128d | 2015-05-21 | 2015-11-18 |  | 847d |  |  |  |
| 357 | 6.1 | **Rule Change (MRP)** |  | 128d | 2015-05-21 | 2015-11-18 |  | 847d |  |  |  |
| 358 | 6.1.1 | Notice of consultation | milestone | 0d | 2015-05-21 | 2015-05-21 |  | 826d | 0d | finish no earlier than 2015-05-21 | AEMC |
| 359 | 6.1.2 | Consultation submissions |  | 29d | 2015-05-22 | 2015-07-02 | 358 | 826d | 0d |  | Industry |
| 360 | 6.1.3 | Draft Determination |  | 36d | 2015-07-03 | 2015-08-21 | 359 | 826d | 0d |  | AEMC |
| 361 | 6.1.4 | Consultation submissions (draft) |  | 30d | 2015-08-24 | 2015-10-02 | 360 | 826d | 0d |  | Industry |
| 362 | 6.1.5 | Final Determination |  | 33d | 2015-10-05 | 2015-11-18 | 361 | 826d |  |  | AEMC |
| 363 | 7 | **NSW ACT Gas Retail Project (NAGRP)** |  | 230d | 2015-06-03 | 2016-04-29 |  | 737d |  |  |  |
| 364 | 7.1 | Project duration (NAGRP) |  | 230d | 2015-06-03 | 2016-04-29 |  | 716d |  | finish no earlier than 2016-04-29 |  |

Notes:
- 356: Non PoC project - potential risk to PoC project / Text Note: Non PoC project - potential risk to PoC project
- 363: Non PoC project - for noting as potential impact on PoC resources / Text Note: Non PoC project - for noting as potential impact on PoC resources
